# Project Management for MS Website

Schedule from MS Project, 2011-11-24 to 2012-03-20, status date 2011-12-06, 7.4 hours a day, costs in £.
Training file
IPSO FACTO Training

## Calendars

- ipsofacto: Mon-Fri 08:00-12:00, 13:00-16:24; Sat-Sun off.

## Resources

| Resource | Rate | Notes |
| --- | --- | --- |
| Project Director | 10 | Responsible for management of the project at a strategic level. |
| Project Manager | 6 | Responsible for the delivery of a quality project on-schedule, within budget, with a satisfied Acceptor and a motivated project team. |
| Acceptor | 5 | Key individual within the business organization who is the principal interface with the project team and who has the authority to accept all deliverables and resolve all project issues (sometimes referred to as the Project Sponsor). |
| Application Architect | 4 | Defines the major application systems needed to support the enterprise. During systems development, the Application Architect defines the application solution. |
| Technical Architect | 3 | Defines the technologies and standards required to support the application and information architectures. During systems development, the Technical Architect defines the technical solution. |
| Quality Assurance Manager | 2 | Responsible for providing confidence to management that the Quality System is being applied. |
| Contracts Manager | 1 | Responsible for managing the contractual interfaces with the customer and with subcontractors. |

## Schedule

| ID | WBS | Task | Type | Duration | Start | Finish | Predecessors | Baseline start | Baseline finish | Baseline duration | Total slack | Constraint | Resources | Work | Cost | Baseline cost |
| --- | --- | --- | --- | --- | --- | --- | --- | --- | --- | --- | --- | --- | --- | --- | --- | --- |
| 1 | IPSO1 | **Project Management (PM)** |  | 83.18d? | 2011-11-24 | 2012-03-20 |  | 2011-11-21 | 2012-03-19 | 85.18d? | 0d |  |  | 720h | 7,316 | 7,252.4 |
| 2 | IPSO1.1 | **Initiating** |  | 8d? | 2011-11-24 | 2011-12-05 |  | 2011-11-21 | 2011-11-30 | 7.84d? | 0d |  |  | 72h | 3,764 | 3,700.4 |
| 3 | IPSO1.1.1 | **Develop Project Charter** |  | 4d? | 2011-11-24 | 2011-11-29 |  | 2011-11-21 | 2011-11-24 | 3.84d? | 0d |  |  | 32h | 3,506 | 3,442.4 |
| 4 | IPSO1.1.1.1 | Identify Goals and Objectives |  | 2.16d | 2011-11-24 | 2011-11-25 |  | 2011-11-21 | 2011-11-22 | 2d | 0d | start no earlier than 2011-11-24 | Project Director | 16h | 410 | 398 |
| 5 | IPSO1.1.1.2 | Develop Strategies and Plans | milestone | 0d | 2011-11-25 | 2011-11-25 | 4 | 2011-11-22 | 2011-11-22 | 0d | 0d |  | Project Director |  |  |  |
| 6 | IPSO1.1.1.3 | Research Previous Experience |  | 2.16d | 2011-11-28 | 2011-11-29 | 5 | 2011-11-22 | 2011-11-23 | 1d | 0d |  | Project Manager | 16h | 96 | 44.4 |
| 7 | IPSO1.1.1.4 | Develop Project Charter | milestone | 0d? | 2011-11-29 | 2011-11-29 | 6 | 2011-11-24 | 2011-11-24 | 0d? | 0d |  | Project Manager; Acceptor |  | 3,000 | 3,000 |
| 8 | IPSO1.1.2 | **Develop Preliminary Project Scope Statement** |  | 4d? | 2011-11-30 | 2011-12-05 | 3 | 2011-11-24 | 2011-11-30 | 4d? | 0d |  |  | 40h | 258 | 258 |
| 9 | IPSO1.1.2.1 | Conduct Planning Workshop |  | 1.08d | 2011-11-30 | 2011-11-30 |  | 2011-11-24 | 2011-11-25 | 1.08d? | 0d |  | Project Director | 8h | 80 | 80 |
| 10 | IPSO1.1.2.2 | Document Project Costs and Benefits |  | 0.54d? | 2011-12-01 | 2011-12-01 | 9 | 2011-11-25 | 2011-11-28 | 0.54d? | 0d |  | Application Architect; Technical Architect; Project Manager | 8h | 38 | 38 |
| 11 | IPSO1.1.2.3 | Develop High Level Work Breakdown Structure |  | 1.08d? | 2011-12-01 | 2011-12-02 | 10 | 2011-11-28 | 2011-11-29 | 1.08d? | 0d |  | Project Manager | 8h | 48 | 48 |
| 12 | IPSO1.1.2.4 | Conduct Peer Review |  | 1.08d? | 2011-12-02 | 2011-12-05 | 11 | 2011-11-29 | 2011-11-30 | 1.08d? | 0d |  | Project Manager | 8h | 48 | 48 |
| 13 | IPSO1.1.2.5 | Prepare Preliminary Project Scope Statement |  | 0.54d? | 2011-12-05 | 2011-12-05 | 12 | 2011-11-30 | 2011-11-30 | 0.54d? | 0d |  | Project Manager; Acceptor | 8h | 44 | 44 |
| 14 | IPSO1.2 | **Planning** |  | 26.72d? | 2011-12-06 | 2012-01-11 | 2 | 2011-11-30 | 2012-01-10 | 28.88d? | 0d |  |  | 248h | 1,292 | 1,292 |
| 15 | IPSO1.2.1 | **Set Up Project Environment** |  | 3.72d? | 2011-12-06 | 2011-12-09 |  | 2011-11-30 | 2011-12-08 | 5.88d? | 0d |  |  | 32h | 160 | 160 |
| 16 | IPSO1.2.1.1 | Prepare Facilities |  | 1.08d? | 2011-12-06 | 2011-12-06 |  | 2011-11-30 | 2011-12-01 | 1.08d? | 0d |  | Project Manager | 8h | 48 | 48 |
| 17 | IPSO1.2.1.2 | Set Up Project Standards and Procedures |  | 1.08d? | 2011-12-07 | 2011-12-07 | 16 | 2011-12-06 | 2011-12-06 | 1.08d? | 0d | start no earlier than 2011-12-06 | Quality Assurance Manager | 8h | 16 | 16 |
| 18 | IPSO1.2.1.3 | Set Up Project Management Tools |  | 0.72d? | 2011-12-08 | 2011-12-08 | 17 | 2011-12-07 | 2011-12-07 | 0.72d? | 0d |  | Project Manager [150%] | 8h | 48 | 48 |
| 19 | IPSO1.2.1.4 | Set Up Project Book |  | 1.08d? | 2011-12-08 | 2011-12-09 | 18 | 2011-12-07 | 2011-12-08 | 1.08d? | 0d |  | Project Manager | 8h | 48 | 48 |
| 20 | IPSO1.2.2 | **Define Scope** |  | 4d? | 2011-12-09 | 2011-12-15 | 15 | 2011-12-08 | 2011-12-14 | 4d? | 0d |  |  | 32h | 192 | 192 |
| 21 | IPSO1.2.2.1 | Document Scope Management Plan |  | 1.08d? | 2011-12-09 | 2011-12-12 |  | 2011-12-08 | 2011-12-09 | 1.08d? | 0d |  | Project Manager | 8h | 48 | 48 |
| 22 | IPSO1.2.2.2 | Specify Deliverables and Acceptance Criteria |  | 1.08d? | 2011-12-12 | 2011-12-13 | 21 | 2011-12-09 | 2011-12-12 | 1.08d? | 0d |  | Project Manager | 8h | 48 | 48 |
| 23 | IPSO1.2.2.3 | Define Scope |  | 1.08d? | 2011-12-13 | 2011-12-14 | 22 | 2011-12-12 | 2011-12-13 | 1.08d? | 0d |  | Project Manager | 8h | 48 | 48 |
| 24 | IPSO1.2.2.4 | Document Assumptions |  | 1.08d? | 2011-12-14 | 2011-12-15 | 23 | 2011-12-13 | 2011-12-14 | 1.08d? | 0d |  | Project Manager | 8h | 48 | 48 |

Notes:
- 1: A set of methods and techniques designed to ensure successful delivery projects (large complex projects are often managed by a Project Management Office using this methodology) in a cost-effective, schedule-compressed manner. / Text1: VPEND<VP ID="0_14624" TYP="0"><VP ID="0_103544" TYP="2" /></VP>
- 2: The Initiating Stage does the preliminary analysis to define the project objectives and ensures that further project work is authorized. / Text1: VPEND<VP ID="0_134424" TYP="0" />
- 3: The Project Charter is developed to formally authorize a project. The Project Charter contrains the high level definition of the project and the business justification for the project. / Text1: VPEND<VP ID="0_168547" TYP="0" />
- 4: Define the primary goals and objectives for the project. / Text1: VPDATA:<VP ID="0_80816" TYP="0"><VP ID="0_97923" TYP="3" /><VP ID="0_80996" TYP="2"><VP ID="0_141944" TYP="3" /><VP ID="0_92093" TYP="3" /><VP ID="0_81772" TYP="3" /></VP><VP ID="0_113117" TYP="2"><VP ID="0_141946" TYP="3" /></VP><VP ID="0_17301" TYP="1" / Text2: VPEND/></VP> / Text7: Goals and Objectives, List of Constraints
- 5: Understand the business organization and its personnel and formulate high level strategies and plans to ensure achievement of objectives. / Text1: VPDATA:<VP ID="0_17185" TYP="0"><VP ID="0_108287" TYP="3" /><VP ID="0_17253" TYP="2" /><VP ID="0_20340" TYP="2"><VP ID="0_79735" TYP="3" /><VP ID="0_79733" TYP="3" /><VP ID="0_79736" TYP="3" /><VP ID="0_79731" TYP="3" /><VP ID="0_22284" TYP="3" /></VP><VP / Text2: VPEND ID="0_13058" TYP="2"><VP ID="0_87966" TYP="3" /></VP><VP ID="0_17301" TYP="1" /></VP> / Text7: Strategies and Plans
- 6: Research previous experience with similar projects and with similar technologies and obtain sample materials. / Text1: VPEND<VP ID="0_17200" TYP="0"><VP ID="0_106881" TYP="3" /><VP ID="0_17296" TYP="2" /><VP ID="0_17303" TYP="1" /></VP> / Text7: Sample Materials
- 7: Develop the Project Charter and present it for approval to proceed with the project. / Text1: VPEND<VP ID="0_134438" TYP="0"><VP ID="0_134441" TYP="2"><VP ID="0_134448" TYP="3" /></VP><VP ID="0_17303" TYP="1" /><VP ID="0_20510" TYP="1" /></VP> / Text7: Project Charter
- 8: The preliminary steps necessary to develop the project's goals and objectives and secure commitment to continue the project. / Text1: VPEND<VP ID="0_134428" TYP="0" />
- 9: Conduct an internal planning session to think through all elements of the project, identify the critical success factors, and map out the project approach. / Text1: VPDATA:<VP ID="0_17202" TYP="0"><VP ID="0_87966" TYP="3" /><VP ID="0_17265" TYP="2"><VP ID="0_141948" TYP="3" /></VP><VP ID="0_17293" TYP="2"><VP ID="0_79736" TYP="3" /><VP ID="0_79731" TYP="3" /></VP><VP ID="0_17294" TYP="2"><VP ID="0_81232" TYP="3" /><V / Text2: VPENDP ID="0_81237" TYP="3" /><VP ID="0_81243" TYP="3" /><VP ID="0_81247" TYP="3" /></VP><VP ID="0_13058" TYP="2"><VP ID="0_87966" TYP="3" /></VP><VP ID="0_17301" TYP="1" /></VP> / Text7: Delivery Approach, Meeting Minutes, Action Items
- 10: Perform the cost/benefit analysis for the projects. Document the cash flows, (i.e., benefits minus costs). Document the benefits and risks that cannot be assigned a cash value. / Text1: VPDATA:<VP ID="0_93766" TYP="0"><VP ID="0_11582" TYP="2"><VP ID="0_22576" TYP="3" /></VP><VP ID="0_11581" TYP="2"><VP ID="0_22576" TYP="3" /></VP><VP ID="0_22392" TYP="2"><VP ID="0_22576" TYP="3" /><VP ID="0_22589" TYP="3" /></VP><VP ID="0_18483" TYP="2"> / Text2: VPEND<VP ID="0_21698" TYP="2" /><VP ID="0_21696" TYP="2" /><VP ID="0_21695" TYP="2" /><VP ID="0_21697" TYP="2" /><VP ID="0_107598" TYP="2" /></VP><VP ID="0_12753" TYP="1" /><VP ID="0_12754" TYP="1" /><VP ID="0_17303" TYP="1" /></VP> / Text7: Benefit Estimating Worksheets, Cost Estimating Worksheets
- 11: Completely identify all of the work to be performed and organize the work into manageable pieces (subprojects). / Text1: VPEND<VP ID="0_17205" TYP="0"><VP ID="0_83310" TYP="3" /><VP ID="0_17267" TYP="2"><VP ID="0_141952" TYP="3" /><VP ID="0_18168" TYP="3" /></VP><VP ID="0_23913" TYP="2" /><VP ID="0_17303" TYP="1" /></VP> / Text7: Contract Work Breakdown Structure
- 12: Conduct a peer review session to solicit feedback on the project approach from senior delivery and management personnel from outside the project team. / Text1: VPDATA:<VP ID="0_17203" TYP="0"><VP ID="0_88302" TYP="3" /><VP ID="0_17294" TYP="2"><VP ID="0_81232" TYP="3" /><VP ID="0_81237" TYP="3" /><VP ID="0_81243" TYP="3" /><VP ID="0_81247" TYP="3" /></VP><VP ID="0_17293" TYP="2"><VP ID="0_79736" TYP="3" /><VP ID / Text2: VPEND="0_79731" TYP="3" /></VP><VP ID="0_18479" TYP="2"><VP ID="0_88302" TYP="3" /></VP><VP ID="0_17303" TYP="1" /></VP> / Text7: Action Items, Meeting Minutes
- 13: Consolidate the preliminary planning material developed into the Preliminary Project Scope Statement / Text1: VPEND<VP ID="0_168558" TYP="0"><VP ID="0_168560" TYP="2"><VP ID="0_168568" TYP="3" /></VP><VP ID="0_17303" TYP="1" /><VP ID="0_20510" TYP="1" /></VP> / Text7: Preliminary Project Scope Statement
- 14: The Planning Stage defines the necessary steps to ensure that proper planning is done, during project start-up, before each new phase starts and as part of the change management process / Text1: VPEND<VP ID="0_134450" TYP="0" />
- 15: Ensure that the fundamental project delivery infrastructure is in place (e.g., work space, standards and procedures, project tools). / Text1: VPEND<VP ID="0_80808" TYP="0" />
- 16: Obtain and furnish work space with the appropriate facilities. / Text1: VPEND<VP ID="0_17214" TYP="0"><VP ID="0_134620" TYP="2" /><VP ID="0_17303" TYP="1" /></VP> / Text7: Physical Project Environment
- 17: Define and document the specific standards and procedures to be applied on the project to ensure consistent delivery in accordance with the quality requirements. / Text1: VPDATA:<VP ID="0_17215" TYP="0"><VP ID="0_17276" TYP="2"><VP ID="0_162156" TYP="3" /><VP ID="0_78321" TYP="3" /><VP ID="0_26215" TYP="2"><VP ID="0_162159" TYP="3" /><VP ID="0_78320" TYP="3" /><VP ID="0_77357" TYP="2"><VP ID="0_162162" TYP="3" /><VP ID="0_ / Text2: VPDATA:77827" TYP="3" /></VP><VP ID="0_77358" TYP="2"><VP ID="0_162165" TYP="3" /><VP ID="0_77829" TYP="3" /></VP></VP><VP ID="0_77354" TYP="2"><VP ID="0_162168" TYP="3" /><VP ID="0_78322" TYP="3" /><VP ID="0_77361" TYP="2"><VP ID="0_162171" TYP="3" /><VP / Text3: VPDATA: ID="0_77836" TYP="3" /></VP><VP ID="0_77362" TYP="2"><VP ID="0_162174" TYP="3" /><VP ID="0_77838" TYP="3" /></VP><VP ID="0_77363" TYP="2"><VP ID="0_162177" TYP="3" /><VP ID="0_77840" TYP="3" /></VP><VP ID="0_78274" TYP="2"><VP ID="0_162180" TYP="3 / Text4: VPDATA:" /><VP ID="0_78278" TYP="3" /></VP></VP><VP ID="0_26216" TYP="2"><VP ID="0_162183" TYP="3" /><VP ID="0_78323" TYP="3" /><VP ID="0_77374" TYP="2"><VP ID="0_162186" TYP="3" /><VP ID="0_77842" TYP="3" /></VP><VP ID="0_77375" TYP="2"><VP ID="0_162188" / Text5: VPDATA: TYP="3" /><VP ID="0_77844" TYP="3" /></VP><VP ID="0_77376" TYP="2"><VP ID="0_162191" TYP="3" /><VP ID="0_77846" TYP="3" /></VP><VP ID="0_77377" TYP="2"><VP ID="0_162194" TYP="3" /><VP ID="0_77848" TYP="3" /></VP></VP><VP ID="0_26217" TYP="2"><VP I / Text6: VPDATA:D="0_141964" TYP="3" /></VP><VP ID="0_77356" TYP="2"><VP ID="0_162197" TYP="3" /><VP ID="0_78326" TYP="3" /><VP ID="0_78336" TYP="2"><VP ID="0_162200" TYP="3" /><VP ID="0_78350" TYP="3" /></VP><VP ID="0_78337" TYP="2"><VP ID="0_162203" TYP="3" /><V / Text7: Project Standards and Procedures, Standards and Procedures for Team Performance, Standards and Procedures for General Practices, Standards and Procedures for Meetings, Standards and Procedures for Cost/Schedule Management, Standards and Procedures for Org / Text8: VPDATA:P ID="0_78351" TYP="3" /></VP><VP ID="0_78338" TYP="2"><VP ID="0_162206" TYP="3" /><VP ID="0_78352" TYP="3" /></VP><VP ID="0_78340" TYP="2"><VP ID="0_162209" TYP="3" /><VP ID="0_78353" TYP="3" /></VP><VP ID="0_78341" TYP="2"><VP ID="0_162212" TYP=" / Text9: VPDATA:3" /><VP ID="0_104426" TYP="3" /><VP ID="0_78354" TYP="3" /></VP><VP ID="0_78342" TYP="2"><VP ID="0_162215" TYP="3" /><VP ID="0_104427" TYP="3" /><VP ID="0_78355" TYP="3" /></VP><VP ID="0_78343" TYP="2"><VP ID="0_162218" TYP="3" /><VP ID="0_78356" / Text10: VPENDTYP="3" /></VP></VP><VP ID="0_77360" TYP="2"><VP ID="0_141960" TYP="3" /></VP><VP ID="0_77359" TYP="2"><VP ID="0_162221" TYP="3" /><VP ID="0_77831" TYP="3" /></VP></VP><VP ID="0_17307" TYP="1" /></VP>
- 18: Implement the project management tools to be used by the project team to manage performance. / Text1: VPEND<VP ID="0_17216" TYP="0"><VP ID="0_18348" TYP="2" /><VP ID="0_17303" TYP="1" /></VP> / Text7: Project Management Tools
- 19: Collect and store the project's quality and scope control records in a standard, single location to provide familiar, rapid access to key project management information. / Text1: VPEND<VP ID="0_17217" TYP="0"><VP ID="0_17277" TYP="2"><VP ID="0_16953" TYP="3" /></VP><VP ID="0_17303" TYP="1" /></VP> / Text7: Project Book
- 20: Establish the Project Scope, WBS and Deliverables necessary to ensure that the objectives defined in the Project Charter are met. / Text1: VPEND<VP ID="0_134455" TYP="0"><VP ID="0_106880" TYP="3" /></VP>
- 21: The Scope Management Plan defines the degree of rigor to be applied to the project based on it's size, complexity, risk tolerance and organizational importance. / Text1: VPEND<VP ID="0_168412" TYP="0"><VP ID="0_168415" TYP="2"><VP ID="0_168422" TYP="3" /></VP><VP ID="0_17303" TYP="1" /></VP> / Text7: Scope Management Plan
- 22: Create a clear and unambiguous definition of each deliverable in terms of format, size and quality requirements, and specify the acceptance procedures and acceptance criteria for each deliverable. / Text1: VPEND<VP ID="0_17204" TYP="0"><VP ID="0_17266" TYP="2"><VP ID="0_21652" TYP="3" /></VP><VP ID="0_17303" TYP="1" /></VP> / Text7: Deliverable Specifications
- 23: Establish and maintain a common understanding with the customer of the scope of the project. / Text1: VPDATA:<VP ID="0_83115" TYP="0"><VP ID="0_97924" TYP="3" /><VP ID="0_80999" TYP="2"><VP ID="0_141950" TYP="3" /><VP ID="0_81007" TYP="3" /></VP><VP ID="0_20546" TYP="2"><VP ID="0_16850" TYP="2"><VP ID="0_22045" TYP="3" /><VP ID="0_22046" TYP="3" /></VP><V / Text2: VPDATA:P ID="0_24102" TYP="2"><VP ID="0_95582" TYP="3" /><VP ID="0_125246" TYP="3" /><VP ID="0_18134" TYP="3" /></VP><VP ID="0_13080" TYP="2"><VP ID="0_20466" TYP="3" /></VP><VP ID="0_18488" TYP="2"><VP ID="0_16833" TYP="3" /></VP><VP ID="0_19594" TYP="2" / Text3: VPEND><VP ID="0_144493" TYP="2" /></VP></VP><VP ID="0_17303" TYP="1" /></VP> / Text7: Definition of Project Scope
- 24: Maintain an ongoing list of the assumptions on which the estimates and schedules are based. / Text1: VPEND<VP ID="0_21691" TYP="0"><VP ID="0_127408" TYP="3" /><VP ID="0_21693" TYP="2"><VP ID="0_141956" TYP="3" /><VP ID="0_21746" TYP="3" /></VP><VP ID="0_17303" TYP="1" /></VP> / Text7: List of Assumptions

| ID | WBS | Task | Duration | Start | Finish | Predecessors | Baseline start | Baseline finish | Baseline duration | Total slack | Resources | Work | Cost | Baseline cost | Text5 |
| --- | --- | --- | --- | --- | --- | --- | --- | --- | --- | --- | --- | --- | --- | --- | --- |
| 25 | IPSO1.2.3 | **Develop Project Schedule** | 5d? | 2011-12-15 | 2011-12-22 | 20 | 2011-12-14 | 2011-12-21 | 5d? | 0d |  | 40h | 240 | 240 |  |
| 26 | IPSO1.2.3.1 | Build Work Breakdown Structure | 1.08d? | 2011-12-15 | 2011-12-16 |  | 2011-12-14 | 2011-12-15 | 1.08d? | 0d | Project Manager | 8h | 48 | 48 |  |
| 27 | IPSO1.2.3.2 | Develop Resource Plans | 1.08d? | 2011-12-16 | 2011-12-19 | 26 | 2011-12-15 | 2011-12-16 | 1.08d? | 0d | Project Manager | 8h | 48 | 48 |  |
| 28 | IPSO1.2.3.3 | Prepare Project Estimates | 1.08d? | 2011-12-19 | 2011-12-20 | 27 | 2011-12-16 | 2011-12-19 | 1.08d? | 0d | Project Manager | 8h | 48 | 48 |  |
| 29 | IPSO1.2.3.4 | Define Dependencies and Develop Project Schedule | 1.08d? | 2011-12-20 | 2011-12-21 | 28 | 2011-12-19 | 2011-12-20 | 1.08d? | 0d | Project Manager | 8h | 48 | 48 |  |
| 30 | IPSO1.2.3.5 | Document Assumptions | 1.08d? | 2011-12-21 | 2011-12-22 | 29 | 2011-12-20 | 2011-12-21 | 1.08d? | 0d | Project Manager | 8h | 48 | 48 |  |
| 31 | IPSO1.2.4 | **Develop Risk Plans** | 3d? | 2011-12-22 | 2011-12-27 | 25 | 2011-12-21 | 2011-12-26 | 3d? | 0d |  | 32h | 184 | 184 |  |
| 32 | IPSO1.2.4.1 | Document Risk Management Plan | 0.54d? | 2011-12-22 | 2011-12-23 |  | 2011-12-21 | 2011-12-22 | 0.54d? | 0d | Project Manager; Acceptor | 8h | 44 | 44 |  |
| 33 | IPSO1.2.4.2 | Identify Risks | 1.08d? | 2011-12-23 | 2011-12-26 | 32 | 2011-12-22 | 2011-12-23 | 1.08d? | 0d | Project Manager | 8h | 48 | 48 |  |
| 34 | IPSO1.2.4.3 | Analyze Risks | 1.08d? | 2011-12-26 | 2011-12-27 | 33 | 2011-12-23 | 2011-12-26 | 1.08d? | 0d | Project Manager | 8h | 48 | 48 |  |
| 35 | IPSO1.2.4.4 | Document Risk Management Plans | 0.54d? | 2011-12-27 | 2011-12-27 | 34 | 2011-12-26 | 2011-12-26 | 0.54d? | 0d | Project Manager; Acceptor | 8h | 44 | 44 |  |
| 36 | IPSO1.2.5 | **Plan for Quality** | 0.46d? | 2011-12-27 | 2011-12-28 | 31 | 2011-12-26 | 2011-12-27 | 0.46d? | 0d |  | 8h | 28 | 28 |  |
| 37 | IPSO1.2.5.1 | Document Quality Management Plan | 0.54d? | 2011-12-27 | 2011-12-28 |  | 2011-12-26 | 2011-12-27 | 0.54d? | 0d | Quality Assurance Manager; Acceptor | 8h | 28 | 28 |  |
| 38 | IPSO1.2.6 | **Organize Project Resources** | 2d? | 2011-12-28 | 2011-12-30 | 36 | 2011-12-27 | 2011-12-29 | 2d? | 0d |  | 16h | 160 | 160 |  |
| 39 | IPSO1.2.6.1 | Develop Organization Structure | 1.08d? | 2011-12-28 | 2011-12-29 |  | 2011-12-27 | 2011-12-28 | 1.08d? | 0d | Project Director | 8h | 80 | 80 |  |
| 40 | IPSO1.2.6.2 | Develop Staffing Plan | 1.08d? | 2011-12-29 | 2011-12-30 | 39 | 2011-12-28 | 2011-12-29 | 1.08d? | 0d | Project Director | 8h | 80 | 80 |  |
| 41 | IPSO1.2.7 | **Develop Procurement Plans** | 4.54d? | 2011-12-30 | 2012-01-05 | 38 | 2011-12-29 | 2012-01-04 | 4.54d? | 0d |  | 40h | 56 | 56 |  |
| 42 | IPSO1.2.7.1 | Determine Procurement Requirements | 1.08d? | 2011-12-30 | 2012-01-02 |  | 2011-12-29 | 2011-12-30 | 1.08d? | 0d | Contracts Manager | 8h | 8 | 8 |  |
| 43 | IPSO1.2.7.2 | Define Subcontractor Scope | 1.08d? | 2012-01-02 | 2012-01-03 | 42 | 2011-12-30 | 2012-01-02 | 1.08d? | 0d | Contracts Manager | 8h | 8 | 8 | VPEND></VP> |
| 44 | IPSO1.2.7.3 | Identify Potential Subcontractors | 1.08d? | 2012-01-03 | 2012-01-04 | 43 | 2012-01-02 | 2012-01-03 | 1.08d? | 0d | Contracts Manager | 8h | 8 | 8 |  |
| 45 | IPSO1.2.7.4 | Identify Subcontract Type | 1.08d? | 2012-01-04 | 2012-01-05 | 44 | 2012-01-03 | 2012-01-04 | 1.08d? | 0d | Contracts Manager | 8h | 8 | 8 |  |
| 46 | IPSO1.2.7.5 | Document Subcontractor Management Plan | 0.54d? | 2012-01-05 | 2012-01-05 | 45 | 2012-01-04 | 2012-01-04 | 0.54d? | 0d | Contracts Manager; Acceptor | 8h | 24 | 24 |  |
| 47 | IPSO1.2.8 | **Develop Financial Plan** | 2d? | 2012-01-05 | 2012-01-09 | 41 | 2012-01-04 | 2012-01-06 | 2d? | 0d |  | 16h | 96 | 96 |  |
| 48 | IPSO1.2.8.1 | Prepare Financial Plan | 1.08d? | 2012-01-05 | 2012-01-06 |  | 2012-01-04 | 2012-01-05 | 1.08d? | 0d | Project Manager | 8h | 48 | 48 |  |
| 49 | IPSO1.2.8.2 | Document Assumptions | 1.08d? | 2012-01-06 | 2012-01-09 | 48 | 2012-01-05 | 2012-01-06 | 1.08d? | 0d | Project Manager | 8h | 48 | 48 |  |

Notes:
- 25: Identify and assign project resources, determine project activity and task dependencies, develop task estimates develop the project schedule. / Text1: VPEND<VP ID="0_80807" TYP="0"><VP ID="0_83310" TYP="3" /></VP>
- 26: Develop the project structure in terms of detailed phases, activities, tasks, deliverables, and resources. / Text1: VPEND<VP ID="0_17199" TYP="0"><VP ID="0_83310" TYP="3" /><VP ID="0_17263" TYP="2" /><VP ID="0_23913" TYP="2" /><VP ID="0_17303" TYP="1" /></VP> / Text7: Detailed Work Breakdown Structure
- 27: Identify resources (human and other) that will be required to successfully deliver the project / Text1: VPEND<VP ID="0_134515" TYP="0"><VP ID="0_134520" TYP="2" /><VP ID="0_17303" TYP="1" /></VP> / Text7: Resource Requirements
- 28: Produce a detailed estimates of the costs and material resources required to deliver each component of the Work Breakdown Structure. / Text1: VPDATA:<VP ID="0_80817" TYP="0"><VP ID="0_107001" TYP="3" /><VP ID="0_17268" TYP="2"><VP ID="0_141975" TYP="3" /></VP><VP ID="0_107598" TYP="2" /><VP ID="0_18483" TYP="2"><VP ID="0_21698" TYP="2" /><VP ID="0_21696" TYP="2" /><VP ID="0_21695" TYP="2" /><VP / Text2: VPEND ID="0_21697" TYP="2" /><VP ID="0_107598" TYP="2" /></VP><VP ID="0_17303" TYP="1" /><VP ID="0_76408" TYP="2" /><VP ID="0_75472" TYP="2" /><VP ID="0_75470" TYP="2" /></VP> / Text7: Estimating Package
- 29: Define the milestones and phase dates for each component of the Work Breakdown Structure, and identify the dependencies between the work components (the network logic). / Text1: VPEND<VP ID="0_80818" TYP="0"><VP ID="0_107002" TYP="3" /><VP ID="0_80997" TYP="2"><VP ID="0_21750" TYP="3" /></VP><VP ID="0_24032" TYP="2"><VP ID="0_95557" TYP="2" /></VP><VP ID="0_17303" TYP="1" /></VP> / Text7: Project Schedules
- 30: Maintain an ongoing list of the assumptions on which the estimates and schedules are based. / Text1: VPEND<VP ID="0_21691" TYP="0"><VP ID="0_127408" TYP="3" /><VP ID="0_21693" TYP="2"><VP ID="0_141956" TYP="3" /><VP ID="0_21746" TYP="3" /></VP><VP ID="0_17303" TYP="1" /></VP> / Text7: List of Assumptions
- 31: Identify, analyze and profile project risks, / Text1: VPEND<VP ID="0_134532" TYP="0" />
- 32: Describe the methods and procedures to be used to identify, evaluate, and eliminate or minimize project risks. / Text1: VPEND<VP ID="0_80820" TYP="0"><VP ID="0_17738" TYP="2"><VP ID="0_141958" TYP="3" /><VP ID="0_27000" TYP="3" /></VP><VP ID="0_17303" TYP="1" /><VP ID="0_20510" TYP="1" /></VP> / Text7: Risk Management Plan
- 33: Risk identification identifies the risks which if unmanaged could impact the project. / Text1: VPDATA:<VP ID="0_134538" TYP="0"><VP ID="0_16684" TYP="3" /><VP ID="0_17264" TYP="2"><VP ID="0_81338" TYP="3" /><VP ID="0_26558" TYP="3" /></VP><VP ID="0_18438" TYP="2"><VP ID="0_13061" TYP="2" /><VP ID="0_109723" TYP="2" /><VP ID="0_20341" TYP="2" /><VP / Text2: VPDATA:ID="0_122668" TYP="2" /><VP ID="0_109733" TYP="2" /><VP ID="0_20340" TYP="2"><VP ID="0_79735" TYP="3" /><VP ID="0_79733" TYP="3" /><VP ID="0_79736" TYP="3" /><VP ID="0_79731" TYP="3" /><VP ID="0_22284" TYP="3" /></VP><VP ID="0_128110" TYP="2" /><VP / Text3: VPEND ID="0_16725" TYP="2"><VP ID="0_17147" TYP="3" /></VP><VP ID="0_117136" TYP="2" /><VP ID="0_13069" TYP="2" /><VP ID="0_13058" TYP="2"><VP ID="0_87966" TYP="3" /></VP></VP><VP ID="0_17303" TYP="1" /></VP> / Text7: Risk Management Action Plan
- 34: Qualitative and Quantitative Analysis of a project's risks and impacts. The result is a prioritized list of risks. / Text1: VPDATA:<VP ID="0_134548" TYP="0"><VP ID="0_17264" TYP="2"><VP ID="0_81338" TYP="3" /><VP ID="0_26558" TYP="3" /></VP><VP ID="0_79583" TYP="2"><VP ID="0_97978" TYP="3" /><VP ID="0_79585" TYP="3" /></VP><VP ID="0_23044" TYP="2"><VP ID="0_23064" TYP="3" /><V / Text2: VPDATA:P ID="0_97062" TYP="2" /></VP><VP ID="0_87790" TYP="2"><VP ID="0_87795" TYP="3" /><VP ID="0_87797" TYP="3" /><VP ID="0_87798" TYP="3" /><VP ID="0_87799" TYP="3" /></VP><VP ID="0_24111" TYP="2" /><VP ID="0_134557" TYP="2"><VP ID="0_144501" TYP="2" / Text3: VPEND></VP><VP ID="0_17303" TYP="1" /></VP> / Text7: Risk Management Action Plan, Risk Management Log
- 35: Profile the potential risks to the project by producing specific plans to reduce or eliminate high risk items before they become obstacles to successful project delivery. / Text1: VPDATA:<VP ID="0_17201" TYP="0"><VP ID="0_16684" TYP="3" /><VP ID="0_17264" TYP="2"><VP ID="0_81338" TYP="3" /><VP ID="0_26558" TYP="3" /></VP><VP ID="0_79583" TYP="2"><VP ID="0_97978" TYP="3" /><VP ID="0_79585" TYP="3" /></VP><VP ID="0_18478" TYP="2"><VP / Text2: VPEND ID="0_16684" TYP="3" /><VP ID="0_97978" TYP="3" /><VP ID="0_81338" TYP="3" /><VP ID="0_79585" TYP="3" /><VP ID="0_26558" TYP="3" /></VP><VP ID="0_17303" TYP="1" /><VP ID="0_20510" TYP="1" /></VP> / Text7: Risk Management Action Plan, Risk Management Log
- 36: Prepare the way for a quality project. / Text1: VPEND<VP ID="0_80812" TYP="0"><VP ID="0_88304" TYP="3" /></VP>
- 37: Establish the baseline against which project quality will be measured and describe the methods and procedures to be used for monitoring and verifying project quality. / Text1: VPDATA:<VP ID="0_80832" TYP="0"><VP ID="0_107568" TYP="3" /><VP ID="0_88304" TYP="3" /><VP ID="0_88294" TYP="3" /><VP ID="0_17289" TYP="2"><VP ID="0_16729" TYP="3" /></VP><VP ID="0_81337" TYP="2"><VP ID="0_123122" TYP="2" /></VP><VP ID="0_17307" TYP="1" / Text2: VPEND><VP ID="0_20510" TYP="1" /></VP> / Text7: Quality Management Plan
- 38: Identify and mobilize a productive and motivated project team. / Text1: VPEND<VP ID="0_17210" TYP="0"><VP ID="0_106882" TYP="3" /></VP>
- 39: Create an effective and efficient project organization structure. / Text1: VPDATA:<VP ID="0_17211" TYP="0"><VP ID="0_107571" TYP="3" /><VP ID="0_17272" TYP="2"><VP ID="0_141996" TYP="3" /><VP ID="0_26181" TYP="2"><VP ID="0_16823" TYP="3" /></VP><VP ID="0_26182" TYP="2"><VP ID="0_141992" TYP="3" /></VP><VP ID="0_26183" TYP="2"><V / Text2: VPDATA:P ID="0_81730" TYP="3" /><VP ID="0_18908" TYP="3" /></VP><VP ID="0_26184" TYP="2"><VP ID="0_141994" TYP="3" /><VP ID="0_18910" TYP="3" /><VP ID="0_26197" TYP="3" /></VP><VP ID="0_26185" TYP="2"><VP ID="0_108068" TYP="3" /></VP></VP><VP ID="0_17301" / Text3: VPEND TYP="1" /></VP> / Text7: Organization Structure, Project Organization Chart, Project Management Organization, Project Delivery Organization, Responsibility Assignment Matrix, Mechanisms for Formal Communications
- 40: Identify the skills required for each role within the project structure, the person-day estimates and start and end dates for each role. / Text1: VPEND<VP ID="0_17212" TYP="0"><VP ID="0_107572" TYP="3" /><VP ID="0_17273" TYP="2"><VP ID="0_26537" TYP="3" /><VP ID="0_18915" TYP="3" /></VP><VP ID="0_17301" TYP="1" /></VP> / Text7: Staffing Plan
- 41: To understand and document what needs to be purchased/contracted for the project and how the purchasing/contracting is to be done. / Text1: VPEND<VP ID="0_134577" TYP="0" />
- 42: To understand which project components will be delivered with in-house resources and which will have to be procured from outside vendors/suppliers / Text1: VPEND<VP ID="0_134590" TYP="0"><VP ID="0_92673" TYP="2"><VP ID="0_142006" TYP="3" /></VP><VP ID="0_110541" TYP="2"><VP ID="0_110544" TYP="3" /></VP><VP ID="0_17305" TYP="1" /></VP> / Text7: Statement of Requirements
- 43: Define the scope of work to be accomplished by each project subcontractor. / Text1: VPDATA:<VP ID="0_130022" TYP="0"><VP ID="0_92678" TYP="2"><VP ID="0_142012" TYP="3" /><VP ID="0_80999" TYP="2"><VP ID="0_141950" TYP="3" /><VP ID="0_81007" TYP="3" /></VP><VP ID="0_92673" TYP="2"><VP ID="0_142006" TYP="3" /></VP><VP ID="0_92674" TYP="2">< / Text2: VPDATA:VP ID="0_18146" TYP="3" /></VP><VP ID="0_92675" TYP="2"><VP ID="0_142008" TYP="3" /></VP><VP ID="0_92676" TYP="2"><VP ID="0_142010" TYP="3" /></VP></VP><VP ID="0_92679" TYP="2"><VP ID="0_142014" TYP="3" /><VP ID="0_92673" TYP="2"><VP ID="0_142006" / Text3: VPDATA:TYP="3" /></VP><VP ID="0_80999" TYP="2"><VP ID="0_141950" TYP="3" /><VP ID="0_81007" TYP="3" /></VP><VP ID="0_92674" TYP="2"><VP ID="0_18146" TYP="3" /></VP></VP><VP ID="0_82149" TYP="2"><VP ID="0_123456" TYP="3" /></VP><VP ID="0_18483" TYP="2"><VP / Text4: VPDATA: ID="0_21698" TYP="2" /><VP ID="0_21696" TYP="2" /><VP ID="0_21695" TYP="2" /><VP ID="0_21697" TYP="2" /><VP ID="0_107598" TYP="2" /></VP><VP ID="0_24032" TYP="2"><VP ID="0_95557" TYP="2" /></VP><VP ID="0_23913" TYP="2" /><VP ID="0_17305" TYP="1" / Text7: Acquisition Management Plan, Definition of Project Scope, Statement of Requirements, Statement of Work, Planning Budget, Planning Schedule, Requisition Documents, Statement of Requirements, Definition of Project Scope, Statement of Work
- 44: To develop and qualify a shortlist of potential subcontractors for the project. / Text1: VPEND<VP ID="0_134598" TYP="0"><VP ID="0_134602" TYP="2" /><VP ID="0_17305" TYP="1" /></VP> / Text7: Subcontractor Shortlist
- 45: Identify the appropriate type of contract to be used for each identified procurement requirement. / Text1: VPEND<VP ID="0_134605" TYP="0"><VP ID="0_92674" TYP="2"><VP ID="0_18146" TYP="3" /></VP><VP ID="0_17305" TYP="1" /></VP> / Text7: Statement of Work
- 46: Describe the methods and procedures to be used in subcontracting work. / Text1: VPEND<VP ID="0_80823" TYP="0"><VP ID="0_17292" TYP="2"><VP ID="0_162224" TYP="3" /><VP ID="0_27061" TYP="3" /></VP><VP ID="0_17305" TYP="1" /><VP ID="0_20510" TYP="1" /></VP> / Text7: Subcontractor Management Plan
- 47: Document the expected cash flow as the basis for monitoring the monthly financial performance of the project. / Text1: VPEND<VP ID="0_129442" TYP="0" />
- 48: Translate the estimates and schedule into an expected monthly cash flow as the basis for monitoring the project's financial performance. / Text1: VPEND<VP ID="0_17207" TYP="0"><VP ID="0_107003" TYP="3" /><VP ID="0_17269" TYP="2" /><VP ID="0_17303" TYP="1" /></VP> / Text7: Financial Plan
- 49: Maintain an ongoing list of the assumptions on which the estimates and schedules are based. / Text1: VPEND<VP ID="0_21691" TYP="0"><VP ID="0_127408" TYP="3" /><VP ID="0_21693" TYP="2"><VP ID="0_141956" TYP="3" /><VP ID="0_21746" TYP="3" /></VP><VP ID="0_17303" TYP="1" /></VP> / Text7: List of Assumptions

| ID | WBS | Task | Duration | Start | Finish | Predecessors | Baseline start | Baseline finish | Baseline duration | Total slack | Resources | Work | Cost | Baseline cost | Text7 |
| --- | --- | --- | --- | --- | --- | --- | --- | --- | --- | --- | --- | --- | --- | --- | --- |
| 50 | IPSO1.2.9 | **Develop Project Support Plans** | 1.46d? | 2012-01-09 | 2012-01-11 | 47 | 2012-01-06 | 2012-01-10 | 1.46d? | 0d |  | 24h | 132 | 132 |  |
| 51 | IPSO1.2.9.1 | Document Communications Management Plan | 0.54d? | 2012-01-09 | 2012-01-10 |  | 2012-01-06 | 2012-01-09 | 0.54d? | 0d | Project Manager; Acceptor | 8h | 44 | 44 | Communications Management Plan |
| 52 | IPSO1.2.9.2 | Document Configuration Management Plan | 0.54d? | 2012-01-10 | 2012-01-10 | 51 | 2012-01-09 | 2012-01-09 | 0.54d? | 0d | Project Manager; Acceptor | 8h | 44 | 44 | Configuration Management Plan |
| 53 | IPSO1.2.9.3 | Document Data Management Plan | 0.54d? | 2012-01-10 | 2012-01-11 | 52 | 2012-01-09 | 2012-01-10 | 0.54d? | 0d | Project Manager; Acceptor | 8h | 44 | 44 | Data Management Plan, Configuration Management Plan |
| 54 | IPSO1.2.10 | **Develop Project Management Plan** | 0.54d? | 2012-01-11 | 2012-01-11 | 50 | 2012-01-10 | 2012-01-10 | 0.54d? | 0d |  | 8h | 44 | 44 |  |
| 55 | IPSO1.2.10.1 | Document Project Management Plan | 0.54d? | 2012-01-11 | 2012-01-11 |  | 2012-01-10 | 2012-01-10 | 0.54d? | 0d | Project Manager; Acceptor | 8h | 44 | 44 | Project Management Plan |
| 56 | IPSO1.3 | **Executing** | 18d? | 2012-01-11 | 2012-02-06 | 14 | 2012-01-10 | 2012-02-03 | 18d? | 0d |  | 144h | 744 | 744 |  |
| 57 | IPSO1.3.1 | **Acquire Project Team** | 3d? | 2012-01-11 | 2012-01-16 |  | 2012-01-10 | 2012-01-13 | 3d? | 0d |  | 24h | 208 | 208 |  |
| 58 | IPSO1.3.1.1 | Obtain Resources | 1.08d? | 2012-01-11 | 2012-01-12 |  | 2012-01-10 | 2012-01-11 | 1.08d? | 0d | Project Director | 8h | 80 | 80 | Staff Rotation Plan, Action Items, Project Team Directory |
| 59 | IPSO1.3.1.2 | Conduct Team Orientation | 1.08d? | 2012-01-12 | 2012-01-13 | 58 | 2012-01-11 | 2012-01-12 | 1.08d? | 0d | Project Director | 8h | 80 | 80 | Orientation Package |
| 60 | IPSO1.3.1.3 | Assign Responsibilities | 1.08d? | 2012-01-13 | 2012-01-16 | 59 | 2012-01-12 | 2012-01-13 | 1.08d? | 0d | Project Manager | 8h | 48 | 48 | Project and Personal Objectives |
| 61 | IPSO1.3.2 | **Direct and Manage Project Execution** | 5d? | 2012-01-16 | 2012-01-23 | 57 | 2012-01-13 | 2012-01-20 | 5d? | 0d |  | 40h | 240 | 240 |  |
| 62 | IPSO1.3.2.1 | Manage Data Items | 1.08d? | 2012-01-16 | 2012-01-17 |  | 2012-01-13 | 2012-01-16 | 1.08d? | 0d | Project Manager | 8h | 48 | 48 | Data Management Reports |
| 63 | IPSO1.3.2.2 | Manage Configuration Items | 1.08d? | 2012-01-17 | 2012-01-18 | 62 | 2012-01-16 | 2012-01-17 | 1.08d? | 0d | Project Manager | 8h | 48 | 48 | Configuration Management Reports |
| 64 | IPSO1.3.2.3 | Manage Process Data | 1.08d? | 2012-01-18 | 2012-01-19 | 63 | 2012-01-17 | 2012-01-18 | 1.08d? | 0d | Project Manager | 8h | 48 | 48 | Project Summary |
| 65 | IPSO1.3.2.4 | Provide General Office Support | 1.08d? | 2012-01-19 | 2012-01-20 | 64 | 2012-01-18 | 2012-01-19 | 1.08d? | 0d | Project Manager | 8h | 48 | 48 | General Office Support |
| 66 | IPSO1.3.2.5 | Administer Project Security Processes | 1.08d? | 2012-01-20 | 2012-01-23 | 65 | 2012-01-19 | 2012-01-20 | 1.08d? | 0d | Project Manager | 8h | 48 | 48 | Security Administration |
| 67 | IPSO1.3.3 | **Manage Team Performance** | 2d? | 2012-01-23 | 2012-01-25 | 61 | 2012-01-20 | 2012-01-24 | 2d? | 0d |  | 16h | 128 | 128 |  |
| 68 | IPSO1.3.3.1 | Provide Team Training | 1.08d? | 2012-01-23 | 2012-01-24 |  | 2012-01-20 | 2012-01-23 | 1.08d? | 0d | Project Manager | 8h | 48 | 48 | Training Needs Analysis |
| 69 | IPSO1.3.3.2 | Recognize Success | 1.08d? | 2012-01-24 | 2012-01-25 | 68 | 2012-01-23 | 2012-01-24 | 1.08d? | 0d | Project Director | 8h | 80 | 80 | Recognition Programs |
| 70 | IPSO1.3.4 | **Assure Quality** | 4d? | 2012-01-25 | 2012-01-31 | 67 | 2012-01-24 | 2012-01-30 | 4d? | 0d |  | 32h | 64 | 64 |  |
| 71 | IPSO1.3.4.1 | Participate in Walk-throughs and Reviews | 1.08d? | 2012-01-25 | 2012-01-26 |  | 2012-01-24 | 2012-01-25 | 1.08d? | 0d | Quality Assurance Manager | 8h | 16 | 16 | Walk-through/Review Reports, Action Items |
| 72 | IPSO1.3.4.2 | Conduct Inspections and Audits | 1.08d? | 2012-01-26 | 2012-01-27 | 71 | 2012-01-25 | 2012-01-26 | 1.08d? | 0d | Quality Assurance Manager | 8h | 16 | 16 | Inspection and Audit Reports, Action Items |
| 73 | IPSO1.3.4.3 | Conduct Project Reviews | 1.08d? | 2012-01-27 | 2012-01-30 | 72 | 2012-01-26 | 2012-01-27 | 1.08d? | 0d | Quality Assurance Manager | 8h | 16 | 16 | Project Review, Action Items |
| 74 | IPSO1.3.4.4 | Facilitate Continuous Improvement | 1.08d? | 2012-01-30 | 2012-01-31 | 73 | 2012-01-27 | 2012-01-30 | 1.08d? | 0d | Quality Assurance Manager | 8h | 16 | 16 | Corrective Action Request |

Notes:
- 50: Document the Risk, Configuration and Data Management Plans which will be used to define these aspects of the project delivery approach. / Text1: VPEND<VP ID="0_80809" TYP="0" />
- 51: Describe the methods and procedures to be used to identify and document the project communications requirements. / Text1: VPEND<VP ID="0_134622" TYP="0"><VP ID="0_134627" TYP="2"><VP ID="0_141973" TYP="3" /></VP><VP ID="0_17303" TYP="1" /><VP ID="0_20510" TYP="1" /></VP>
- 52: Describe the methods and procedures to be used to establish effective identification, control, accounting, and auditing of controlled items throughout the development life cycle. / Text1: VPEND<VP ID="0_80821" TYP="0"><VP ID="0_17290" TYP="2"><VP ID="0_141962" TYP="3" /><VP ID="0_27060" TYP="3" /></VP><VP ID="0_17303" TYP="1" /><VP ID="0_20510" TYP="1" /></VP>
- 53: Describe the methods and procedures to be used to implement and maintain a Data Management System for the identification, acquisition, distribution, delivery, and status reporting of data. / Text1: VPDATA:<VP ID="0_80822" TYP="0"><VP ID="0_17291" TYP="2"><VP ID="0_141966" TYP="3" /></VP><VP ID="0_17303" TYP="1" /><VP ID="0_20510" TYP="1" /><VP ID="0_17290" TYP="2"><VP ID="0_141962" TYP="3" /><VP ID="0_27060" TYP="3" /></VP><VP ID="0_17303" TYP="1" / Text2: VPEND><VP ID="0_20510" TYP="1" /></VP>
- 54: The Project Management Plan contains the results of the Project Planning Phase and provides the definition against which the project will be delivered. / Text1: VPEND<VP ID="0_168444" TYP="0" />
- 55: Establish the baseline for scope, budget, schedule, and quality, against which project performance is measured and all changes to the project are controlled. / Text1: VPEND<VP ID="0_80819" TYP="0"><VP ID="0_88291" TYP="3" /><VP ID="0_17288" TYP="2"><VP ID="0_81554" TYP="3" /></VP><VP ID="0_17303" TYP="1" /><VP ID="0_20510" TYP="1" /></VP>
- 56: Coordinating the people and other resources required to deliver the project / Text1: VPEND<VP ID="0_134633" TYP="0" />
- 57: Assemble, deliver team orientation and assign project responsibilities / Text1: VPEND<VP ID="0_168469" TYP="0" />
- 58: Negotiate for resources and prepare action plans to identify any staffing deficiencies. / Text1: VPDATA:<VP ID="0_17213" TYP="0"><VP ID="0_85951" TYP="3" /><VP ID="0_17275" TYP="2"><VP ID="0_141998" TYP="3" /></VP><VP ID="0_17294" TYP="2"><VP ID="0_81232" TYP="3" /><VP ID="0_81237" TYP="3" /><VP ID="0_81243" TYP="3" /><VP ID="0_81247" TYP="3" /></VP> / Text2: VPEND<VP ID="0_114266" TYP="2"><VP ID="0_142000" TYP="3" /></VP><VP ID="0_17301" TYP="1" /></VP>
- 59: Provide a formal orientation to the project and build a common understanding within the team. / Text1: VPEND<VP ID="0_17218" TYP="0"><VP ID="0_16754" TYP="3" /><VP ID="0_80998" TYP="2"><VP ID="0_81004" TYP="3" /></VP><VP ID="0_17301" TYP="1" /></VP>
- 60: Delegate responsibility for work assignments and witness commitment. / Text1: VPEND<VP ID="0_81532" TYP="0"><VP ID="0_107111" TYP="3" /><VP ID="0_17274" TYP="2"><VP ID="0_142026" TYP="3" /><VP ID="0_26538" TYP="3" /></VP><VP ID="0_88000" TYP="2"><VP ID="0_144499" TYP="2" /></VP><VP ID="0_17303" TYP="1" /></VP>
- 61: Manage the data that supports the project and implement the discipline of configuration management. / Text1: VPEND<VP ID="0_17233" TYP="0"><VP ID="0_107014" TYP="3" /></VP>
- 62: Identify, control and report upon the scheduling, publishing and release of all formal data items, and the replacement of obsolete versions, in accordance with the terms of the project plan. / Text1: VPEND<VP ID="0_17235" TYP="0"><VP ID="0_18350" TYP="2"><VP ID="0_21553" TYP="3" /></VP><VP ID="0_17303" TYP="1" /></VP>
- 63: Identify, control, and report upon selected baseline items, such as the project description, product specifications and process specifications, which formally define the project. / Text1: VPEND<VP ID="0_17236" TYP="0"><VP ID="0_88295" TYP="3" /><VP ID="0_88300" TYP="3" /><VP ID="0_18351" TYP="2" /><VP ID="0_17303" TYP="1" /></VP>
- 64: Collect and maintain a standard set of data on the project's processes, metrics, and lessons learned. / Text1: VPEND<VP ID="0_17238" TYP="0"><VP ID="0_17271" TYP="2"><VP ID="0_142020" TYP="3" /></VP><VP ID="0_17303" TYP="1" /></VP>
- 65: Provide general office support such as producing correspondence, document production and distribution services, and maintaining files and logs. / Text1: VPEND<VP ID="0_17251" TYP="0"><VP ID="0_142022" TYP="2" /><VP ID="0_17303" TYP="1" /></VP>
- 66: Design and implement procedures to ensure adequate project security, including such things as badges, sign-in registers, electronic lock accessibility, and monitoring the security related practices in all project facilities. / Text1: VPEND<VP ID="0_17252" TYP="0"><VP ID="0_142024" TYP="2" /><VP ID="0_17303" TYP="1" /></VP>
- 67: Optimize the performance of team members in achieving project goals. / Text1: VPEND<VP ID="0_80811" TYP="0"><VP ID="0_107010" TYP="3" /><VP ID="0_88301" TYP="3" /></VP>
- 68: Provide training to members of the project team (including business and subcontractor personnel) in the project-specific methodology, tools, or technology, as required. / Text1: VPEND<VP ID="0_17219" TYP="0"><VP ID="0_88298" TYP="3" /><VP ID="0_81546" TYP="2"><VP ID="0_85299" TYP="3" /></VP><VP ID="0_76644" TYP="2" /><VP ID="0_17303" TYP="1" /></VP>
- 69: Develop and implement means to recognize and reward quality service, creativity, innovation, and success. / Text1: VPEND<VP ID="0_17230" TYP="0"><VP ID="0_78444" TYP="2" /><VP ID="0_88000" TYP="2"><VP ID="0_144499" TYP="2" /></VP><VP ID="0_17301" TYP="1" /></VP>
- 70: Monitor the levels of quality being achieved. / Text1: VPEND<VP ID="0_80813" TYP="0"><VP ID="0_107013" TYP="3" /><VP ID="0_88300" TYP="3" /><VP ID="0_88305" TYP="3" /></VP>
- 71: Participate in structured walk-throughs and reviews of project deliverables with members of the project team, to represent quality concerns. / Text1: VPDATA:<VP ID="0_17240" TYP="0"><VP ID="0_88302" TYP="3" /><VP ID="0_89519" TYP="2"><VP ID="0_16768" TYP="3" /></VP><VP ID="0_17294" TYP="2"><VP ID="0_81232" TYP="3" /><VP ID="0_81237" TYP="3" /><VP ID="0_81243" TYP="3" /><VP ID="0_81247" TYP="3" /></VP>< / Text2: VPENDVP ID="0_18479" TYP="2"><VP ID="0_88302" TYP="3" /></VP><VP ID="0_17307" TYP="1" /></VP>
- 72: Conduct inspections and audits to determine the completeness and consistency of processes and deliverables. / Text1: VPDATA:<VP ID="0_17241" TYP="0"><VP ID="0_104426" TYP="3" /><VP ID="0_104427" TYP="3" /><VP ID="0_18352" TYP="2"><VP ID="0_142029" TYP="3" /></VP><VP ID="0_17294" TYP="2"><VP ID="0_81232" TYP="3" /><VP ID="0_81237" TYP="3" /><VP ID="0_81243" TYP="3" /><VP / Text2: VPDATA: ID="0_81247" TYP="3" /></VP><VP ID="0_114093" TYP="2"><VP ID="0_113891" TYP="3" /><VP ID="0_113888" TYP="3" /><VP ID="0_113887" TYP="3" /><VP ID="0_113890" TYP="3" /><VP ID="0_113854" TYP="3" /><VP ID="0_114124" TYP="3" /><VP ID="0_113885" TYP="3" / Text3: VPDATA: /><VP ID="0_113876" TYP="3" /><VP ID="0_113881" TYP="3" /><VP ID="0_113878" TYP="3" /><VP ID="0_113880" TYP="3" /><VP ID="0_113879" TYP="3" /><VP ID="0_113884" TYP="3" /><VP ID="0_113886" TYP="3" /><VP ID="0_113882" TYP="3" /><VP ID="0_113883" TYP / Text4: VPDATA:="3" /><VP ID="0_82184" TYP="3" /><VP ID="0_82183" TYP="3" /><VP ID="0_113877" TYP="3" /><VP ID="0_82185" TYP="3" /></VP><VP ID="0_17307" TYP="1" /><VP ID="0_114145" TYP="2" /><VP ID="0_114147" TYP="2" /><VP ID="0_114146" TYP="2" /><VP ID="0_114133 / Text5: VPDATA:" TYP="2" /><VP ID="0_114136" TYP="2" /><VP ID="0_114140" TYP="2" /><VP ID="0_114157" TYP="2" /><VP ID="0_81775" TYP="2" /><VP ID="0_114158" TYP="2" /><VP ID="0_114128" TYP="2" /><VP ID="0_114160" TYP="2" /><VP ID="0_81774" TYP="2" /><VP ID="0_1141 / Text6: VPEND61" TYP="2" /><VP ID="0_114163" TYP="2" /><VP ID="0_114162" TYP="2" /></VP>
- 73: Review and appraise the project to assess and increase the probability of project success. / Text1: VPDATA:<VP ID="0_17232" TYP="0"><VP ID="0_104171" TYP="3" /><VP ID="0_88297" TYP="3" /><VP ID="0_88296" TYP="3" /><VP ID="0_17287" TYP="2"><VP ID="0_81228" TYP="3" /><VP ID="0_81229" TYP="3" /></VP><VP ID="0_17294" TYP="2"><VP ID="0_81232" TYP="3" /><VP I / Text2: VPDATA:D="0_81237" TYP="3" /><VP ID="0_81243" TYP="3" /><VP ID="0_81247" TYP="3" /></VP><VP ID="0_103828" TYP="2"><VP ID="0_104171" TYP="3" /><VP ID="0_117329" TYP="3" /><VP ID="0_81228" TYP="3" /><VP ID="0_17778" TYP="3" /></VP><VP ID="0_17307" TYP="1" / Text3: VPEND></VP>
- 74: Investigate the causes of problems and analyze work operations to identify process improvements and reduce or eliminate failures. / Text1: VPDATA:<VP ID="0_17228" TYP="0"><VP ID="0_88297" TYP="3" /><VP ID="0_88296" TYP="3" /><VP ID="0_17284" TYP="2"><VP ID="0_79813" TYP="3" /><VP ID="0_79812" TYP="3" /></VP><VP ID="0_115147" TYP="2"><VP ID="0_115162" TYP="3" /><VP ID="0_115159" TYP="3" /><VP / Text2: VPEND ID="0_115161" TYP="3" /><VP ID="0_115156" TYP="3" /><VP ID="0_115160" TYP="3" /><VP ID="0_115155" TYP="3" /><VP ID="0_115158" TYP="3" /><VP ID="0_115157" TYP="3" /></VP><VP ID="0_17307" TYP="1" /></VP>

| ID | WBS | Task | Duration | Start | Finish | Predecessors | Baseline start | Baseline finish | Baseline duration | Total slack | Resources | Work | Cost | Baseline cost |
| --- | --- | --- | --- | --- | --- | --- | --- | --- | --- | --- | --- | --- | --- | --- |
| 75 | IPSO1.3.5 | **Manage Project Communication** | 1d? | 2012-01-31 | 2012-02-01 | 70 | 2012-01-30 | 2012-01-31 | 1d? | 0d |  | 8h | 80 | 80 |
| 76 | IPSO1.3.5.1 | Review Progress | 1.08d? | 2012-01-31 | 2012-02-01 |  | 2012-01-30 | 2012-01-31 | 1.08d? | 0d | Project Director | 8h | 80 | 80 |
| 77 | IPSO1.3.6 | **Contracting with Subcontractors** | 3d? | 2012-02-01 | 2012-02-06 | 75 | 2012-01-31 | 2012-02-03 | 3d? | 0d |  | 24h | 24 | 24 |
| 78 | IPSO1.3.6.1 | Issue Requisition Documents | 1.08d? | 2012-02-01 | 2012-02-02 |  | 2012-01-31 | 2012-02-01 | 1.08d? | 0d | Contracts Manager | 8h | 8 | 8 |
| 79 | IPSO1.3.6.2 | Evaluate Responses | 1.08d? | 2012-02-02 | 2012-02-03 | 78 | 2012-02-01 | 2012-02-02 | 1.08d? | 0d | Contracts Manager | 8h | 8 | 8 |
| 80 | IPSO1.3.6.3 | Negotiate Subcontractor Contract | 1.08d? | 2012-02-03 | 2012-02-06 | 79 | 2012-02-02 | 2012-02-03 | 1.08d? | 0d | Contracts Manager | 8h | 8 | 8 |
| 81 | IPSO1.4 | **Monitoring and Controlling** | 25.46d? | 2012-02-06 | 2012-03-13 | 56 | 2012-02-03 | 2012-03-12 | 25.46d? | 0d |  | 216h | 1,276 | 1,276 |
| 82 | IPSO1.4.1 | **Monitor and Control Project Work** | 3d? | 2012-02-06 | 2012-02-09 |  | 2012-02-03 | 2012-02-08 | 3d? | 0d |  | 24h | 144 | 144 |
| 83 | IPSO1.4.1.1 | Authorize Work | 1.08d? | 2012-02-06 | 2012-02-07 |  | 2012-02-03 | 2012-02-06 | 1.08d? | 0d | Project Manager | 8h | 48 | 48 |
| 84 | IPSO1.4.1.2 | Manage Action Items | 1.08d? | 2012-02-07 | 2012-02-08 | 83 | 2012-02-06 | 2012-02-07 | 1.08d? | 0d | Project Manager | 8h | 48 | 48 |
| 85 | IPSO1.4.1.3 | Manage Project Records | 1.08d? | 2012-02-08 | 2012-02-09 | 84 | 2012-02-07 | 2012-02-08 | 1.08d? | 0d | Project Manager | 8h | 48 | 48 |
| 86 | IPSO1.4.2 | **Integrated Change Control** | 4d | 2012-02-09 | 2012-02-15 | 82 | 2012-02-08 | 2012-02-14 | 4d? | 0d |  | 32h | 192 | 192 |
| 87 | IPSO1.4.2.1 | Manage Scope | 1.08d | 2012-02-09 | 2012-02-10 |  | 2012-02-08 | 2012-02-09 | 1.08d? | 0d | Project Manager | 8h | 48 | 48 |
| 88 | IPSO1.4.2.2 | Manage Requirements | 1.08d | 2012-02-10 | 2012-02-13 | 87 | 2012-02-09 | 2012-02-10 | 1.08d? | 0d | Project Manager | 8h | 48 | 48 |
| 89 | IPSO1.4.2.3 | Control Decisions | 1.08d | 2012-02-13 | 2012-02-14 | 88 | 2012-02-10 | 2012-02-13 | 1.08d? | 0d | Project Manager | 8h | 48 | 48 |
| 90 | IPSO1.4.2.4 | Control Changes | 1.08d | 2012-02-14 | 2012-02-15 | 89 | 2012-02-13 | 2012-02-14 | 1.08d? | 0d | Project Manager | 8h | 48 | 48 |
| 91 | IPSO1.4.3 | **Scope Verification** | 0.46d? | 2012-02-15 | 2012-02-16 | 86 | 2012-02-14 | 2012-02-15 | 0.46d? | 0d |  | 8h | 44 | 44 |
| 92 | IPSO1.4.3.1 | Manage Project Acceptance | 0.54d? | 2012-02-15 | 2012-02-16 |  | 2012-02-14 | 2012-02-15 | 0.54d? | 0d | Project Manager; Acceptor | 8h | 44 | 44 |
| 93 | IPSO1.4.4 | **Schedule Control** | 3d? | 2012-02-16 | 2012-02-21 | 91 | 2012-02-15 | 2012-02-20 | 3d? | 0d |  | 24h | 144 | 144 |
| 94 | IPSO1.4.4.1 | Track Status | 1.08d? | 2012-02-16 | 2012-02-17 |  | 2012-02-15 | 2012-02-16 | 1.08d? | 0d | Project Manager | 8h | 48 | 48 |
| 95 | IPSO1.4.4.2 | Maintain Project Schedule | 1.08d? | 2012-02-17 | 2012-02-20 | 94 | 2012-02-16 | 2012-02-17 | 1.08d? | 0d | Project Manager | 8h | 48 | 48 |
| 96 | IPSO1.4.4.3 | Maintain Work Plans | 1.08d? | 2012-02-20 | 2012-02-21 | 95 | 2012-02-17 | 2012-02-20 | 1.08d? | 0d | Project Manager | 8h | 48 | 48 |
| 97 | IPSO1.4.5 | **Manage Finances** | 3d? | 2012-02-21 | 2012-02-24 | 93 | 2012-02-20 | 2012-02-23 | 3d? | 0d |  | 24h | 208 | 208 |
| 98 | IPSO1.4.5.1 | Monitor Cost/Schedule Variance | 1.08d? | 2012-02-21 | 2012-02-22 |  | 2012-02-20 | 2012-02-21 | 1.08d? | 0d | Project Manager | 8h | 48 | 48 |
| 99 | IPSO1.4.5.2 | Control Costs | 1.08d? | 2012-02-22 | 2012-02-23 | 98 | 2012-02-21 | 2012-02-22 | 1.08d? | 0d | Project Director | 8h | 80 | 80 |
| 100 | IPSO1.4.5.3 | Maintain Financial Plan | 1.08d? | 2012-02-23 | 2012-02-24 | 99 | 2012-02-22 | 2012-02-23 | 1.08d? | 0d | Project Director | 8h | 80 | 80 |

Notes:
- 75: Develop and maintain a good working relationship with all the project stakeholders by using effective project communications. / Text1: VPEND<VP ID="0_17184" TYP="0"><VP ID="0_107009" TYP="3" /></VP>
- 76: Maintain frequent formal and informal contact with project stakeholders to review progress and maintain open communication. / Text1: VPDATA:<VP ID="0_17186" TYP="0"><VP ID="0_17294" TYP="2"><VP ID="0_81232" TYP="3" /><VP ID="0_81237" TYP="3" /><VP ID="0_81243" TYP="3" /><VP ID="0_81247" TYP="3" /></VP><VP ID="0_17293" TYP="2"><VP ID="0_79736" TYP="3" /><VP ID="0_79731" TYP="3" /></VP>< / Text2: VPENDVP ID="0_18488" TYP="2"><VP ID="0_16833" TYP="3" /></VP><VP ID="0_16725" TYP="2"><VP ID="0_17147" TYP="3" /></VP><VP ID="0_17301" TYP="1" /></VP> / Text7: Action Items, Meeting Minutes
- 77: Selection and management of any subcontractors required to deliver the project. / Text1: VPEND<VP ID="0_134740" TYP="0" />
- 78: Issue the formal requisition documents to prospective subcontractors. / Text1: VPDATA:<VP ID="0_130026" TYP="0"><VP ID="0_92679" TYP="2"><VP ID="0_142014" TYP="3" /><VP ID="0_92673" TYP="2"><VP ID="0_142006" TYP="3" /></VP><VP ID="0_80999" TYP="2"><VP ID="0_141950" TYP="3" /><VP ID="0_81007" TYP="3" /></VP><VP ID="0_92674" TYP="2">< / Text2: VPDATA:VP ID="0_18146" TYP="3" /></VP></VP><VP ID="0_125855" TYP="2"><VP ID="0_18490" TYP="2"><VP ID="0_22290" TYP="3" /></VP><VP ID="0_20419" TYP="2" /><VP ID="0_24085" TYP="2"><VP ID="0_23591" TYP="3" /><VP ID="0_23599" TYP="3" /><VP ID="0_23600" TYP="3 / Text3: VPEND" /></VP><VP ID="0_22073" TYP="2"><VP ID="0_26460" TYP="3" /></VP><VP ID="0_114209" TYP="2"><VP ID="0_144503" TYP="2" /></VP></VP><VP ID="0_17305" TYP="1" /></VP> / Text7: Requisition Documents, Statement of Requirements, Definition of Project Scope, Statement of Work
- 79: Evaluate responses to the formal requisition documents from prospective subcontractors. / Text1: VPDATA:<VP ID="0_130032" TYP="0"><VP ID="0_92681" TYP="2" /><VP ID="0_92682" TYP="2" /><VP ID="0_92683" TYP="2" /><VP ID="0_17256" TYP="2"><VP ID="0_20259" TYP="3" /><VP ID="0_142031" TYP="3" /></VP><VP ID="0_13087" TYP="2"><VP ID="0_20216" TYP="3" /><VP / Text2: VPENDID="0_20217" TYP="3" /><VP ID="0_20219" TYP="3" /><VP ID="0_20218" TYP="3" /><VP ID="0_108115" TYP="3" /><VP ID="0_108114" TYP="3" /><VP ID="0_95545" TYP="2" /></VP><VP ID="0_17305" TYP="1" /></VP> / Text7: Clarification of Requisition Requirements, Bid Evaluations, Confirmation of Preferred Subcontractor, Supplier Quality Assessment
- 80: Negotiate effective contracts with subcontractors and arrange subcontract signing. / Text1: VPEND<VP ID="0_80815" TYP="0"><VP ID="0_17257" TYP="2" /><VP ID="0_17258" TYP="2" /><VP ID="0_80936" TYP="2" /><VP ID="0_18482" TYP="2" /><VP ID="0_17305" TYP="1" /></VP> / Text7: Non-Disclosure Agreement, Teaming Agreement, Subcontract
- 81: Monitoring and measuring the project performance to ensure that the project is on target (on time, on budget meeting expectations). / Text1: VPEND<VP ID="0_134651" TYP="0" />
- 82: Monitor and control contains the project tasks which validate the overall project direction by validating that the project work is progressing according to the plan. / Text1: VPEND<VP ID="0_168484" TYP="0" />
- 83: Delegate delivery responsibilities for a work package, establish a clear and unambiguous understanding for how the work package is to be delivered, witness commitment, and formally authorize the commencement of work. / Text1: VPEND<VP ID="0_17222" TYP="0"><VP ID="0_107103" TYP="3" /><VP ID="0_17280" TYP="2"><VP ID="0_142018" TYP="3" /><VP ID="0_18094" TYP="3" /></VP><VP ID="0_17303" TYP="1" /></VP> / Text7: Work Authorization Form
- 84: Record, communicate and ensure closure on all action items including changes to the contractual baseline, requirements for information, problem reports and service requests, to facilitate effective decision-making within acceptable time frames. / Text1: VPDATA:<VP ID="0_17227" TYP="0"><VP ID="0_77815" TYP="2"><VP ID="0_18376" TYP="2"><VP ID="0_81232" TYP="3" /></VP><VP ID="0_18375" TYP="2"><VP ID="0_81234" TYP="3" /></VP><VP ID="0_18378" TYP="2"><VP ID="0_81237" TYP="3" /></VP><VP ID="0_18377" TYP="2"><V / Text2: VPDATA:P ID="0_81239" TYP="3" /></VP><VP ID="0_133953" TYP="2"><VP ID="0_133954" TYP="3" /></VP><VP ID="0_133956" TYP="2"><VP ID="0_133958" TYP="3" /></VP><VP ID="0_18380" TYP="2"><VP ID="0_81243" TYP="3" /><VP ID="0_85846" TYP="3" /></VP><VP ID="0_18379" / Text3: VPDATA: TYP="2"><VP ID="0_81241" TYP="3" /><VP ID="0_85847" TYP="3" /></VP><VP ID="0_18389" TYP="2"><VP ID="0_81247" TYP="3" /></VP><VP ID="0_18381" TYP="2"><VP ID="0_81245" TYP="3" /></VP><VP ID="0_133934" TYP="2"><VP ID="0_133936" TYP="3" /></VP><VP ID= / Text4: VPEND"0_133943" TYP="2"><VP ID="0_133945" TYP="3" /></VP><VP ID="0_17255" TYP="2"><VP ID="0_16829" TYP="3" /></VP><VP ID="0_129751" TYP="2"><VP ID="0_129753" TYP="3" /></VP></VP><VP ID="0_17303" TYP="1" /></VP> / Text7: Action Item Reports, Change Request, Change Request Log, Decision Request, Decision Request Log, Information Request, Information Request Log, Fault Report, Fault Report Log, Service Request, Service Request Log, Issue Resolution Request, Issue Log, Accep
- 85: Establish, maintain, and dispose of project records in a way that provides adequate access for team members during the project and long-term retention for use in subsequent projects. / Text1: VPDATA:<VP ID="0_17234" TYP="0"><VP ID="0_17277" TYP="2"><VP ID="0_16953" TYP="3" /></VP><VP ID="0_17273" TYP="2"><VP ID="0_26537" TYP="3" /><VP ID="0_18915" TYP="3" /></VP><VP ID="0_17275" TYP="2"><VP ID="0_141998" TYP="3" /></VP><VP ID="0_114266" TYP="2 / Text2: VPEND"><VP ID="0_142000" TYP="3" /></VP><VP ID="0_18349" TYP="2"><VP ID="0_82201" TYP="3" /></VP><VP ID="0_17303" TYP="1" /></VP> / Text7: Project Book, Staffing Plan, Staff Rotation Plan, Project Team Directory, Project Index
- 86: Maintain a comprehensive, clear, and measurable definition of the project scope and requirements. / Text1: VPEND<VP ID="0_80810" TYP="0"><VP ID="0_107008" TYP="3" /></VP>
- 87: Establish and maintain a common understanding with the Acceptor of the scope of the project. / Text1: VPDATA:<VP ID="0_80824" TYP="0"><VP ID="0_107107" TYP="3" /><VP ID="0_80999" TYP="2"><VP ID="0_141950" TYP="3" /><VP ID="0_81007" TYP="3" /></VP><VP ID="0_18488" TYP="2"><VP ID="0_16833" TYP="3" /></VP><VP ID="0_20546" TYP="2"><VP ID="0_16850" TYP="2"><VP / Text2: VPDATA: ID="0_22045" TYP="3" /><VP ID="0_22046" TYP="3" /></VP><VP ID="0_24102" TYP="2"><VP ID="0_95582" TYP="3" /><VP ID="0_125246" TYP="3" /><VP ID="0_18134" TYP="3" /></VP><VP ID="0_13080" TYP="2"><VP ID="0_20466" TYP="3" /></VP><VP ID="0_18488" TYP="2 / Text3: VPEND"><VP ID="0_16833" TYP="3" /></VP><VP ID="0_19594" TYP="2"><VP ID="0_144493" TYP="2" /></VP></VP><VP ID="0_17303" TYP="1" /></VP> / Text7: Definition of Project Scope
- 88: Establish and maintain a common understanding with the customer of the requirements that will be addressed by the project. / Text1: VPDATA:<VP ID="0_21544" TYP="0"><VP ID="0_107109" TYP="3" /><VP ID="0_88290" TYP="3" /><VP ID="0_88300" TYP="3" /><VP ID="0_22751" TYP="2"><VP ID="0_124964" TYP="3" /><VP ID="0_22559" TYP="3" /></VP><VP ID="0_18488" TYP="2"><VP ID="0_16833" TYP="3" /></VP / Text2: VPEND><VP ID="0_82149" TYP="2"><VP ID="0_123456" TYP="3" /></VP><VP ID="0_13081" TYP="2" /><VP ID="0_17303" TYP="1" /></VP> / Text7: Baseline Traceability Matrix
- 89: Ensure that the project team is provided with the information and decisions necessary to keep the project on track. / Text1: VPDATA:<VP ID="0_80825" TYP="0"><VP ID="0_18378" TYP="2"><VP ID="0_81237" TYP="3" /></VP><VP ID="0_18377" TYP="2"><VP ID="0_81239" TYP="3" /></VP><VP ID="0_133953" TYP="2"><VP ID="0_133954" TYP="3" /></VP><VP ID="0_133956" TYP="2"><VP ID="0_133958" TYP="3 / Text2: VPEND" /></VP><VP ID="0_18488" TYP="2"><VP ID="0_16833" TYP="3" /></VP><VP ID="0_17303" TYP="1" /></VP> / Text7: Decision Request, Decision Request Log, Information Request, Information Request Log
- 90: Record and obtain approval for any and every change to the approved project baselines. / Text1: VPDATA:<VP ID="0_80826" TYP="0"><VP ID="0_18376" TYP="2"><VP ID="0_81232" TYP="3" /></VP><VP ID="0_18375" TYP="2"><VP ID="0_81234" TYP="3" /></VP><VP ID="0_18488" TYP="2"><VP ID="0_16833" TYP="3" /></VP><VP ID="0_17303" TYP="1" /><VP ID="0_87977" TYP="2" / Text2: VPEND/></VP> / Text7: Change Request, Change Request Log
- 91: Scope verification ensures that the project deliverables are formally accepted. / Text1: VPEND<VP ID="0_168492" TYP="0" />
- 92: Obtain acceptance of deliverables and final sign-off that the project has been completed. / Text1: VPEND<VP ID="0_129463" TYP="0"><VP ID="0_107340" TYP="3" /><VP ID="0_17255" TYP="2"><VP ID="0_16829" TYP="3" /></VP><VP ID="0_129751" TYP="2"><VP ID="0_129753" TYP="3" /></VP><VP ID="0_17303" TYP="1" /><VP ID="0_20510" TYP="1" /></VP> / Text7: Acceptance Document, Acceptance Sign-off Log
- 93: Maintaining the Project Schedule to ensure it remains accurate and current based on approved Change Requests and revised estimates to complete from Project Team Members. / Text1: VPEND<VP ID="0_134656" TYP="0"><VP ID="0_107012" TYP="3" /></VP>
- 94: Track detailed progress against each activity and task, re-assess personal commitment, and re-forecast the remaining effort to completion and the expected completion date, on a regular weekly basis. / Text1: VPEND<VP ID="0_17223" TYP="0"><VP ID="0_107105" TYP="3" /><VP ID="0_88292" TYP="3" /><VP ID="0_17281" TYP="2"><VP ID="0_18098" TYP="3" /></VP><VP ID="0_17303" TYP="1" /></VP> / Text7: Project Tracking Document
- 95: Perform the appropriate updates to the project schedule to account for current project status, approved project changes and other project issues. / Text1: VPEND<VP ID="0_168497" TYP="0"><VP ID="0_80997" TYP="2"><VP ID="0_21750" TYP="3" /></VP><VP ID="0_24032" TYP="2"><VP ID="0_95557" TYP="2" /></VP><VP ID="0_17303" TYP="1" /></VP> / Text7: Project Schedules
- 96: Maintain a current and reliable version of the project work plans, based on approved changes and current estimates to completion. / Text1: VPDATA:<VP ID="0_23110" TYP="0"><VP ID="0_83319" TYP="3" /><VP ID="0_21889" TYP="2"><VP ID="0_80997" TYP="2"><VP ID="0_21750" TYP="3" /></VP><VP ID="0_21693" TYP="2"><VP ID="0_141956" TYP="3" /><VP ID="0_21746" TYP="3" /></VP><VP ID="0_113117" TYP="2"><VP / Text2: VPEND ID="0_141946" TYP="3" /></VP><VP ID="0_17263" TYP="2" /><VP ID="0_17269" TYP="2" /></VP><VP ID="0_17303" TYP="1" /></VP> / Text7: Work Plans, Project Schedules, List of Assumptions, List of Constraints, Detailed Work Breakdown Structure, Financial Plan
- 97: Manage the monthly cash flow of the project, including the forecasted estimates to complete for the remainder of the project. / Text1: VPEND<VP ID="0_129446" TYP="0"><VP ID="0_107012" TYP="3" /></VP>
- 98: Analyze cost and schedule variances from plan and implement corrective action. / Text1: VPDATA:<VP ID="0_17226" TYP="0"><VP ID="0_107012" TYP="3" /><VP ID="0_17283" TYP="2"><VP ID="0_142033" TYP="3" /></VP><VP ID="0_17294" TYP="2"><VP ID="0_81232" TYP="3" /><VP ID="0_81237" TYP="3" /><VP ID="0_81243" TYP="3" /><VP ID="0_81247" TYP="3" /></VP / Text2: VPEND><VP ID="0_24119" TYP="2" /><VP ID="0_18488" TYP="2"><VP ID="0_16833" TYP="3" /></VP><VP ID="0_17303" TYP="1" /></VP> / Text7: Project Cost/Schedule Performance Report, Action Items
- 99: Control project costs and expenses so as deliver the project on budget. / Text1: VPEND<VP ID="0_129695" TYP="0"><VP ID="0_129702" TYP="2" /><VP ID="0_17301" TYP="1" /></VP> / Text7: Approved Project Charges
- 100: Reconcile the project's financial data with the corporate financial system and update the financial estimates to complete for the remainder of the project / Text1: VPEND<VP ID="0_129448" TYP="0"><VP ID="0_17269" TYP="2" /><VP ID="0_17301" TYP="1" /></VP> / Text7: Financial Plan

| ID | WBS | Task | Duration | Start | Finish | Predecessors | Baseline start | Baseline finish | Baseline duration | Total slack | Resources | Work | Cost | Baseline cost |
| --- | --- | --- | --- | --- | --- | --- | --- | --- | --- | --- | --- | --- | --- | --- |
| 101 | IPSO1.4.6 | **Perform Quality Control** | 3d? | 2012-02-24 | 2012-02-29 | 97 | 2012-02-23 | 2012-02-28 | 3d? | 0d |  | 24h | 48 | 48 |
| 102 | IPSO1.4.6.1 | Control Quality | 1.08d? | 2012-02-24 | 2012-02-27 |  | 2012-02-23 | 2012-02-24 | 1.08d? | 0d | Quality Assurance Manager | 8h | 16 | 16 |
| 103 | IPSO1.4.6.2 | Participate in Testing | 1.08d? | 2012-02-27 | 2012-02-28 | 102 | 2012-02-24 | 2012-02-27 | 1.08d? | 0d | Quality Assurance Manager | 8h | 16 | 16 |
| 104 | IPSO1.4.6.3 | Measure Quality Levels | 1.08d? | 2012-02-28 | 2012-02-29 | 103 | 2012-02-27 | 2012-02-28 | 1.08d? | 0d | Quality Assurance Manager | 8h | 16 | 16 |
| 105 | IPSO1.4.7 | **Manage Project Team** | 4d? | 2012-02-29 | 2012-03-06 | 101 | 2012-02-28 | 2012-03-05 | 4d? | 0d |  | 32h | 192 | 192 |
| 106 | IPSO1.4.7.1 | Manage Communications | 1.08d? | 2012-02-29 | 2012-03-01 |  | 2012-02-28 | 2012-02-29 | 1.08d? | 0d | Project Manager | 8h | 48 | 48 |
| 107 | IPSO1.4.7.2 | Meet With Team | 1.08d? | 2012-03-01 | 2012-03-02 | 106 | 2012-02-29 | 2012-03-01 | 1.08d? | 0d | Project Manager | 8h | 48 | 48 |
| 108 | IPSO1.4.7.3 | Monitor Team Morale | 1.08d? | 2012-03-02 | 2012-03-05 | 107 | 2012-03-01 | 2012-03-02 | 1.08d? | 0d | Project Manager | 8h | 48 | 48 |
| 109 | IPSO1.4.7.4 | Conduct Team Performance Reviews | 1.08d? | 2012-03-05 | 2012-03-06 | 108 | 2012-03-02 | 2012-03-05 | 1.08d? | 0d | Project Manager | 8h | 48 | 48 |
| 110 | IPSO1.4.8 | **Produce Performance Reports** | 1d? | 2012-03-06 | 2012-03-07 | 105 | 2012-03-05 | 2012-03-06 | 1d? | 0d |  | 16h | 88 | 88 |
| 111 | IPSO1.4.8.1 | Report Weekly Status | 0.54d? | 2012-03-06 | 2012-03-06 |  | 2012-03-05 | 2012-03-05 | 0.54d? | 0d | Project Manager; Acceptor | 8h | 44 | 44 |
| 112 | IPSO1.4.8.2 | Report Monthly Status | 0.54d? | 2012-03-06 | 2012-03-07 | 111 | 2012-03-05 | 2012-03-06 | 0.54d? | 0d | Project Manager; Acceptor | 8h | 44 | 44 |
| 113 | IPSO1.4.9 | **Manage Stakeholders** | 2d? | 2012-03-07 | 2012-03-09 | 110 | 2012-03-06 | 2012-03-08 | 2d? | 0d |  | 16h | 160 | 160 |
| 114 | IPSO1.4.9.1 | Monitor Satisfaction | 1.08d? | 2012-03-07 | 2012-03-08 |  | 2012-03-06 | 2012-03-07 | 1.08d? | 0d | Project Director | 8h | 80 | 80 |
| 115 | IPSO1.4.9.2 | Resolve Issues | 1.08d? | 2012-03-08 | 2012-03-09 | 114 | 2012-03-07 | 2012-03-08 | 1.08d? | 0d | Project Director | 8h | 80 | 80 |
| 116 | IPSO1.4.10 | **Risk Monitoring and Control** | 1d? | 2012-03-09 | 2012-03-12 | 113 | 2012-03-08 | 2012-03-09 | 1d? | 0d |  | 8h | 48 | 48 |
| 117 | IPSO1.4.10.1 | Manage Risks | 1.08d? | 2012-03-09 | 2012-03-12 |  | 2012-03-08 | 2012-03-09 | 1.08d? | 0d | Project Manager | 8h | 48 | 48 |
| 118 | IPSO1.4.11 | **Contract Administration** | 1d? | 2012-03-12 | 2012-03-13 | 116 | 2012-03-09 | 2012-03-12 | 1d? | 0d |  | 8h | 8 | 8 |
| 119 | IPSO1.4.11.1 | Manage Subcontractor Contract | 1.08d? | 2012-03-12 | 2012-03-13 |  | 2012-03-09 | 2012-03-12 | 1.08d? | 0d | Contracts Manager | 8h | 8 | 8 |
| 120 | IPSO1.5 | **Closing** | 5d? | 2012-03-13 | 2012-03-20 | 81 | 2012-03-12 | 2012-03-19 | 5d? | 0d |  | 40h | 240 | 240 |
| 121 | IPSO1.5.1 | **Close Project** | 5d? | 2012-03-13 | 2012-03-20 |  | 2012-03-12 | 2012-03-19 | 5d? | 0d |  | 40h | 240 | 240 |
| 122 | IPSO1.5.1.1 | Assess Satisfaction | 1.08d? | 2012-03-13 | 2012-03-14 |  | 2012-03-12 | 2012-03-13 | 1.08d? | 0d | Project Manager | 8h | 48 | 48 |
| 123 | IPSO1.5.1.2 | Summarize Project Results and Lessons Learned | 1.08d? | 2012-03-14 | 2012-03-15 | 122 | 2012-03-13 | 2012-03-14 | 1.08d? | 0d | Project Manager | 8h | 48 | 48 |
| 124 | IPSO1.5.1.3 | Review and Recognize Team Performance | 1.08d? | 2012-03-15 | 2012-03-16 | 123 | 2012-03-14 | 2012-03-15 | 1.08d? | 0d | Project Manager | 8h | 48 | 48 |
| 125 | IPSO1.5.1.4 | Close Out the Project Records | 1.08d? | 2012-03-16 | 2012-03-19 | 124 | 2012-03-15 | 2012-03-16 | 1.08d? | 0d | Project Manager | 8h | 48 | 48 |
| 126 | IPSO1.5.1.5 | Review and Reconcile Financial Performance | 1.08d? | 2012-03-19 | 2012-03-20 | 125 | 2012-03-16 | 2012-03-19 | 1.08d? | 0d | Project Manager | 8h | 48 | 48 |

Notes:
- 101: Implement and manage a program to ensure the project quality and implement continual improvement of work operations. / Text1: VPEND<VP ID="0_80814" TYP="0"><VP ID="0_88307" TYP="3" /></VP>
- 102: Measure and ensure that the project meets defined Quality Standards. / Text1: VPDATA:<VP ID="0_134677" TYP="0"><VP ID="0_88294" TYP="3" /><VP ID="0_17294" TYP="2"><VP ID="0_81232" TYP="3" /><VP ID="0_81237" TYP="3" /><VP ID="0_81243" TYP="3" /><VP ID="0_81247" TYP="3" /></VP><VP ID="0_109958" TYP="2"><VP ID="0_114093" TYP="2"><VP I / Text2: VPDATA:D="0_113891" TYP="3" /><VP ID="0_113888" TYP="3" /><VP ID="0_113887" TYP="3" /><VP ID="0_113890" TYP="3" /><VP ID="0_113854" TYP="3" /><VP ID="0_114124" TYP="3" /><VP ID="0_113885" TYP="3" /><VP ID="0_113876" TYP="3" /><VP ID="0_113881" TYP="3" />< / Text3: VPDATA:VP ID="0_113878" TYP="3" /><VP ID="0_113880" TYP="3" /><VP ID="0_113879" TYP="3" /><VP ID="0_113884" TYP="3" /><VP ID="0_113886" TYP="3" /><VP ID="0_113882" TYP="3" /><VP ID="0_113883" TYP="3" /><VP ID="0_82184" TYP="3" /><VP ID="0_82183" TYP="3" / Text4: VPDATA:><VP ID="0_113877" TYP="3" /><VP ID="0_82185" TYP="3" /></VP><VP ID="0_109401" TYP="2" /><VP ID="0_81337" TYP="2"><VP ID="0_123122" TYP="2" /></VP><VP ID="0_19627" TYP="2" /></VP><VP ID="0_13072" TYP="2"><VP ID="0_20452" TYP="3" /><VP ID="0_95555" / Text5: VPDATA:TYP="2" /></VP><VP ID="0_19888" TYP="2"><VP ID="0_20450" TYP="3" /></VP><VP ID="0_13071" TYP="2"><VP ID="0_20453" TYP="3" /></VP><VP ID="0_19577" TYP="2"><VP ID="0_20445" TYP="3" /></VP><VP ID="0_19580" TYP="2"><VP ID="0_20449" TYP="3" /><VP ID="0_ / Text6: VPEND123857" TYP="3" /></VP><VP ID="0_17307" TYP="1" /><VP ID="0_87240" TYP="2" /></VP> / Text7: Action Items
- 103: Witness testing, conduct verification testing, and conduct acceptance testing of subcontracted components. / Text1: VPDATA:<VP ID="0_17242" TYP="0"><VP ID="0_17294" TYP="2"><VP ID="0_81232" TYP="3" /><VP ID="0_81237" TYP="3" /><VP ID="0_81243" TYP="3" /><VP ID="0_81247" TYP="3" /></VP><VP ID="0_18443" TYP="2"><VP ID="0_114093" TYP="2"><VP ID="0_113891" TYP="3" /><VP ID / Text2: VPDATA:="0_113888" TYP="3" /><VP ID="0_113887" TYP="3" /><VP ID="0_113890" TYP="3" /><VP ID="0_113854" TYP="3" /><VP ID="0_114124" TYP="3" /><VP ID="0_113885" TYP="3" /><VP ID="0_113876" TYP="3" /><VP ID="0_113881" TYP="3" /><VP ID="0_113878" TYP="3" /><V / Text3: VPDATA:P ID="0_113880" TYP="3" /><VP ID="0_113879" TYP="3" /><VP ID="0_113884" TYP="3" /><VP ID="0_113886" TYP="3" /><VP ID="0_113882" TYP="3" /><VP ID="0_113883" TYP="3" /><VP ID="0_82184" TYP="3" /><VP ID="0_82183" TYP="3" /><VP ID="0_113877" TYP="3" /> / Text4: VPDATA:<VP ID="0_82185" TYP="3" /></VP><VP ID="0_18490" TYP="2"><VP ID="0_22290" TYP="3" /></VP><VP ID="0_13082" TYP="2"><VP ID="0_23020" TYP="3" /></VP><VP ID="0_18479" TYP="2"><VP ID="0_88302" TYP="3" /></VP><VP ID="0_13081" TYP="2" /></VP><VP ID="0_173 / Text5: VPEND07" TYP="1" /></VP> / Text7: Action Items
- 104: Interpret project measurements as the basis for the continual improvement and optimization of work processes. / Text1: VPEND<VP ID="0_17244" TYP="0"><VP ID="0_88303" TYP="3" /><VP ID="0_88304" TYP="3" /><VP ID="0_88294" TYP="3" /><VP ID="0_18353" TYP="2"><VP ID="0_20326" TYP="3" /></VP><VP ID="0_17307" TYP="1" /></VP> / Text7: Quality Metrics and Trends
- 105: Tracking team performance, providing feedback, resolving issues and coordinating changes to the team to ensure optimal project performance. / Text1: VPEND<VP ID="0_168505" TYP="0"><VP ID="0_88301" TYP="3" /></VP>
- 106: Develop and implement effective communications among all members of the project team. / Text1: VPDATA:<VP ID="0_17229" TYP="0"><VP ID="0_107115" TYP="3" /><VP ID="0_17285" TYP="2" /><VP ID="0_88000" TYP="2"><VP ID="0_144499" TYP="2" /></VP><VP ID="0_103137" TYP="2"><VP ID="0_103149" TYP="3" /><VP ID="0_103150" TYP="3" /><VP ID="0_103240" TYP="3" /> / Text2: VPEND<VP ID="0_103247" TYP="3" /></VP><VP ID="0_17303" TYP="1" /></VP> / Text7: Project Communications
- 107: Meet regularly with team members to review status, share experiences, provide suggestions, and resolve problems and concerns. / Text1: VPDATA:<VP ID="0_17225" TYP="0"><VP ID="0_107113" TYP="3" /><VP ID="0_22284" TYP="3" /><VP ID="0_17293" TYP="2"><VP ID="0_79736" TYP="3" /><VP ID="0_79731" TYP="3" /></VP><VP ID="0_20340" TYP="2"><VP ID="0_79735" TYP="3" /><VP ID="0_79733" TYP="3" /><VP I / Text2: VPDATA:D="0_79736" TYP="3" /><VP ID="0_79731" TYP="3" /><VP ID="0_22284" TYP="3" /></VP><VP ID="0_88000" TYP="2"><VP ID="0_144499" TYP="2" /></VP><VP ID="0_18478" TYP="2"><VP ID="0_16684" TYP="3" /><VP ID="0_97978" TYP="3" /><VP ID="0_81338" TYP="3" /><VP / Text3: VPEND ID="0_79585" TYP="3" /><VP ID="0_26558" TYP="3" /></VP><VP ID="0_17303" TYP="1" /></VP> / Text7: Meeting Minutes
- 108: Monitor team morale and take action to correct problem areas. / Text1: VPEND<VP ID="0_80831" TYP="0"><VP ID="0_81000" TYP="2"><VP ID="0_95777" TYP="3" /><VP ID="0_81009" TYP="3" /></VP><VP ID="0_109723" TYP="2" /><VP ID="0_88000" TYP="2"><VP ID="0_144499" TYP="2" /></VP><VP ID="0_17303" TYP="1" /></VP> / Text7: Team Surveys
- 109: Record and communicate the accomplishments of team members, and appraise their skills, to facilitate career development. / Text1: VPDATA:<VP ID="0_17231" TYP="0"><VP ID="0_86093" TYP="3" /><VP ID="0_86092" TYP="3" /><VP ID="0_86090" TYP="3" /><VP ID="0_86091" TYP="3" /><VP ID="0_17286" TYP="2" /><VP ID="0_88000" TYP="2"><VP ID="0_144499" TYP="2" /></VP><VP ID="0_20341" TYP="2" /><VP / Text2: VPEND ID="0_17303" TYP="1" /></VP> / Text7: Performance Review
- 110: Monitor and report on the costs, schedule, and technical performance of the project. / Text1: VPEND<VP ID="0_17221" TYP="0" />
- 111: Summarize and communicate the accomplishments for the reporting period, the objectives for the coming period, problems (if any), the status of outstanding risk items, and suggestions for dealing with issues and problems. / Text1: VPDATA:<VP ID="0_17224" TYP="0"><VP ID="0_107293" TYP="3" /><VP ID="0_17282" TYP="2"><VP ID="0_16704" TYP="3" /><VP ID="0_16706" TYP="3" /></VP><VP ID="0_79583" TYP="2"><VP ID="0_97978" TYP="3" /><VP ID="0_79585" TYP="3" /></VP><VP ID="0_17298" TYP="2" /> / Text2: VPDATA:<VP ID="0_17294" TYP="2"><VP ID="0_81232" TYP="3" /><VP ID="0_81237" TYP="3" /><VP ID="0_81243" TYP="3" /><VP ID="0_81247" TYP="3" /></VP><VP ID="0_18478" TYP="2"><VP ID="0_16684" TYP="3" /><VP ID="0_97978" TYP="3" /><VP ID="0_81338" TYP="3" /><VP / Text3: VPENDID="0_79585" TYP="3" /><VP ID="0_26558" TYP="3" /></VP><VP ID="0_20341" TYP="2" /><VP ID="0_17303" TYP="1" /><VP ID="0_20510" TYP="1" /></VP> / Text7: Project Weekly Status Report, Risk Management Log, Project Tracking Summary Report, Action Items
- 112: Keep project status visible to Project Stakeholders by providing an appropriate summary of project status on a regular monthly basis. / Text1: VPDATA:<VP ID="0_81249" TYP="0"><VP ID="0_107295" TYP="3" /><VP ID="0_17299" TYP="2"><VP ID="0_81226" TYP="3" /></VP><VP ID="0_17294" TYP="2"><VP ID="0_81232" TYP="3" /><VP ID="0_81237" TYP="3" /><VP ID="0_81243" TYP="3" /><VP ID="0_81247" TYP="3" /></VP> / Text2: VPEND<VP ID="0_17303" TYP="1" /><VP ID="0_20510" TYP="1" /></VP> / Text7: Project Monthly Status Report, Action Items
- 113: All project stakeholders must be effectively communicated to to ensure a common consistent view of the project exists. It is important to ensure that the project stakeholders are satisfied with the project results. / Text1: VPEND<VP ID="0_168517" TYP="0" />
- 114: Monitor how well the stakeholder's expectations for quality service delivery are being met. / Text1: VPDATA:<VP ID="0_17188" TYP="0"><VP ID="0_17254" TYP="2"><VP ID="0_95582" TYP="3" /><VP ID="0_125246" TYP="3" /><VP ID="0_18134" TYP="3" /></VP><VP ID="0_17294" TYP="2"><VP ID="0_81232" TYP="3" /><VP ID="0_81237" TYP="3" /><VP ID="0_81243" TYP="3" /><VP I / Text2: VPENDD="0_81247" TYP="3" /></VP><VP ID="0_24102" TYP="2"><VP ID="0_95582" TYP="3" /><VP ID="0_125246" TYP="3" /><VP ID="0_18134" TYP="3" /></VP><VP ID="0_17301" TYP="1" /></VP> / Text7: Stakeholder Satisfaction Measures, Action Items
- 115: Identify, track and resolve issues affecting the project. / Text1: VPDATA:<VP ID="0_17187" TYP="0"><VP ID="0_133934" TYP="2"><VP ID="0_133936" TYP="3" /></VP><VP ID="0_133943" TYP="2"><VP ID="0_133945" TYP="3" /></VP><VP ID="0_17295" TYP="2" /><VP ID="0_18481" TYP="2" /><VP ID="0_109723" TYP="2" /><VP ID="0_17301" TYP="1 / Text2: VPEND" /></VP> / Text7: Issue Resolution Request, Issue Log, Working Papers
- 116: Managing the Risk Log and acting on Risk Management Action Plans as required to ensure the project stays on schedule. / Text1: VPEND<VP ID="0_134662" TYP="0" />
- 117: Manage the Risk Log and the Risk Action plans to ensure that risks do not impact the project. / Text1: VPDATA:<VP ID="0_134666" TYP="0"><VP ID="0_17264" TYP="2"><VP ID="0_81338" TYP="3" /><VP ID="0_26558" TYP="3" /></VP><VP ID="0_79583" TYP="2"><VP ID="0_97978" TYP="3" /><VP ID="0_79585" TYP="3" /></VP><VP ID="0_18478" TYP="2"><VP ID="0_16684" TYP="3" /><V / Text2: VPENDP ID="0_97978" TYP="3" /><VP ID="0_81338" TYP="3" /><VP ID="0_79585" TYP="3" /><VP ID="0_26558" TYP="3" /></VP><VP ID="0_17303" TYP="1" /></VP> / Text7: Risk Management Action Plan, Risk Management Log
- 118: Ensure that all contract terms and conditions, both buyer and seller, are adhered to during the life of the contract / Text1: VPEND<VP ID="0_168523" TYP="0" />
- 119: Manage the relationship between the acquisition organization and the subcontracting organization. / Text1: VPDATA:<VP ID="0_130037" TYP="0"><VP ID="0_88293" TYP="3" /><VP ID="0_92678" TYP="2"><VP ID="0_142012" TYP="3" /><VP ID="0_80999" TYP="2"><VP ID="0_141950" TYP="3" /><VP ID="0_81007" TYP="3" /></VP><VP ID="0_92673" TYP="2"><VP ID="0_142006" TYP="3" /></VP / Text2: VPDATA:><VP ID="0_92674" TYP="2"><VP ID="0_18146" TYP="3" /></VP><VP ID="0_92675" TYP="2"><VP ID="0_142008" TYP="3" /></VP><VP ID="0_92676" TYP="2"><VP ID="0_142010" TYP="3" /></VP></VP><VP ID="0_17261" TYP="2" /><VP ID="0_92687" TYP="2" /><VP ID="0_18488 / Text3: VPEND" TYP="2"><VP ID="0_16833" TYP="3" /></VP><VP ID="0_17305" TYP="1" /></VP> / Text7: Acquisition Management Plan, Definition of Project Scope, Statement of Requirements, Statement of Work, Planning Budget, Planning Schedule, Contract Files, Subcontractor Payments
- 120: Close out the project upon completion. / Text1: VPEND<VP ID="0_129436" TYP="0" />
- 121: Make sure that the project is properly closed down, either when project delivery is complete or when the project is terminated for whatever reason. / Text1: VPEND<VP ID="0_81855" TYP="0"><VP ID="0_107335" TYP="3" /></VP>
- 122: Document the overall satisfaction with the project. / Text1: VPDATA:<VP ID="0_129464" TYP="0"><VP ID="0_95586" TYP="2"><VP ID="0_95582" TYP="3" /><VP ID="0_125246" TYP="3" /></VP><VP ID="0_24102" TYP="2"><VP ID="0_95582" TYP="3" /><VP ID="0_125246" TYP="3" /><VP ID="0_18134" TYP="3" /></VP><VP ID="0_17303" TYP="1" / Text2: VPEND/></VP> / Text7: Stakeholder Satisfaction Form
- 123: Work with the project team to capture relevant experience and lessons learned for the benefit of future projects. / Text1: VPEND<VP ID="0_129465" TYP="0"><VP ID="0_17271" TYP="2"><VP ID="0_142020" TYP="3" /></VP><VP ID="0_17303" TYP="1" /></VP> / Text7: Project Summary
- 124: Complete performance reviews for each team member, recognize efforts and accomplishments, and celebrate success. / Text1: VPEND<VP ID="0_129475" TYP="0"><VP ID="0_17286" TYP="2" /><VP ID="0_78444" TYP="2" /><VP ID="0_20341" TYP="2" /><VP ID="0_17303" TYP="1" /></VP> / Text7: Performance Review, Recognition Programs
- 125: Update and archive project documentation and make sure that all close out conditions have been met. / Text1: VPEND<VP ID="0_81852" TYP="0"><VP ID="0_129517" TYP="2" /><VP ID="0_129510" TYP="2" /><VP ID="0_17303" TYP="1" /></VP> / Text7: Project Archives, Project Completion
- 126: Make sure that all invoices have been delivered and all payments made. / Text1: VPEND<VP ID="0_129488" TYP="0"><VP ID="0_19517" TYP="2" /><VP ID="0_17303" TYP="1" /></VP> / Text7: Payments

| ID | WBS | Task | Type | Duration | Start | Finish | Predecessors | Baseline start | Baseline finish | Baseline duration | Total slack | Resources | Text7 |
| --- | --- | --- | --- | --- | --- | --- | --- | --- | --- | --- | --- | --- | --- |
| 127 | IPSO1.5.2 | **Contract Closure** |  | 0d? | 2012-03-20 | 2012-03-20 | 121 | 2012-03-19 | 2012-03-19 | 0d? | 0d |  |  |
| 128 | IPSO1.5.2.1 | Close Contract | milestone | 0d? | 2012-03-20 | 2012-03-20 |  | 2012-03-19 | 2012-03-19 | 0d? | 0d | Contracts Manager | Contract Files, Subcontractor Payments |

Notes:
- 127: Blab / Text1: VPEND<VP ID="0_168529" TYP="0" />
- 128: Specific actions required to ensure acceptance of deliverables, process final payments and archive and close out project contract files. / Text1: VPEND<VP ID="0_168537" TYP="0"><VP ID="0_17261" TYP="2" /><VP ID="0_92687" TYP="2" /><VP ID="0_17305" TYP="1" /></VP>
